# Maxwell Sites Pumping and Generating Facilities CP2

Schedule from MS Project, 2022-01-03 to 2031-12-18.

## Calendars

- Standard: Mon-Fri 08:00-12:00, 13:00-17:00; Sat-Sun off.

## Schedule

| ID | WBS | Task | Type | Duration | Start | Finish | Predecessors | Total slack | Free slack | Constraint |
| --- | --- | --- | --- | --- | --- | --- | --- | --- | --- | --- |
| 1 | 1 | Start Task Order 3 - Preliminary Engineering | milestone | 0d | 2022-01-03 | 2022-01-03 |  | 2599d |  | start no earlier than 2022-01-03 |
| 2 | 2 | Determine Construction Packaging & Delivery Methods | manual | 149d | 2022-01-03 | 2022-07-28 |  |  |  |  |
| 3 | 3 | Real Estate Team Gain Access for Surveying & Geotech Investigation |  | 500d | 2022-01-17 | 2024-02-16 |  | 2044d |  | start no earlier than 2022-01-17 |
| 4 | 4 | Topographic Survey and Mapping |  | 225d | 2022-01-03 | 2022-11-11 |  | 667d | 557d | finish no earlier than 2022-11-11 |
| 5 | 5 | Water Rights Permit Issued | milestone | 0d | 2024-09-26 | 2024-09-26 |  | 179d | 69d | start no earlier than 2024-09-26 |
| 6 | 6 | **Final EIR / EIS** |  | 130d | 2023-06-01 | 2023-11-30 |  | 454d |  |  |
| 7 | 6.1 | Final EIR CEQA Adoption | milestone | 0d | 2023-06-01 | 2023-06-01 |  | 524d | 0d | start no earlier than 2023-06-01 |
| 8 | 6.2 | Final EIS NEPA ROD | milestone | 0d | 2023-11-30 | 2023-11-30 |  | 454d | 286d | start no earlier than 2023-11-30 |
| 9 | 7 | WIFEA EPA Loan Closed | milestone | 0d | 2024-10-31 | 2024-10-31 |  | 154d | 44d | start no earlier than 2024-10-31 |
| 10 | 8 | Investor Commitment | milestone | 0d | 2024-10-24 | 2024-10-24 |  | 159d | 49d | start no earlier than 2024-10-24 |
| 11 | 9 | NTP for 60% Design Activities | milestone | 0d | 2025-01-01 | 2025-01-01 | 4, 5, 9, 10, 7 | 110d | 0d | start no earlier than 2025-01-01 |
| 12 | 10 | **Geotech Investigations MSPG Investigations** |  | 954d | 2022-08-01 | 2026-03-26 |  | 742d |  |  |
| 13 | 10.1 | **Phase 1 Geotech investigation for Preliminary (30%) Design** |  | 538d | 2022-08-01 | 2024-08-21 |  | 1911d |  |  |
| 14 | 10.1.1 | **Federal Access (USBR)** |  | 240d | 2022-08-01 | 2023-06-30 |  | 2209d |  |  |
| 15 | 10.1.1.1 | Right of Entry, Negotiated |  | 2mo | 2022-08-01 | 2022-09-23 |  | 2209d | 0d | start no earlier than 2022-08-01 |
| 16 | 10.1.1.2 | Environmental Survey, Report Prep & Clearance |  | 4mo | 2022-09-26 | 2023-01-13 | 15 | 2209d | 0d |  |
| 17 | 10.1.1.3 | Cultural Survey Report Prep and Clearance |  | 4mo | 2022-09-26 | 2023-01-13 | 15 | 2209d | 0d |  |
| 18 | 10.1.1.4 | Geotechnical Field Investigation and Report |  | 6mo | 2023-01-16 | 2023-06-30 | 16, 17 | 2209d |  |  |
| 19 | 10.1.2 | **Private Access** |  | 427d | 2023-01-03 | 2024-08-21 |  | 1911d |  |  |
| 20 | 10.1.2.1 | Right of Entry Negotiated |  | 3mo | 2023-01-03 | 2023-03-27 |  | 2078d | 167d | start no earlier than 2023-01-03 |
| 21 | 10.1.2.2 | Right of Entry Court Ordered |  | 6mo | 2023-06-01 | 2023-11-15 | 7 | 1911d | 0d | start no earlier than 2023-01-03 |
| 22 | 10.1.2.3 | Environmental Survey, Report Prep & Clearance |  | 4mo | 2023-11-16 | 2024-03-06 | 20, 21 | 1911d | 0d |  |
| 23 | 10.1.2.4 | Cultural Survey Report Prep and Clearance |  | 4mo | 2023-11-16 | 2024-03-06 | 20, 21 | 1911d | 0d |  |
| 24 | 10.1.2.5 | Geotechnical Field Investigation and Report |  | 6mo | 2024-03-07 | 2024-08-21 | 22, 23 | 1911d | 0d |  |
| 25 | 10.1.3 | P1 Geotechnical Investigation Complete | milestone | 0d | 2024-08-21 | 2024-08-21 | 24 | 1911d |  |  |

| ID | WBS | Task | Type | Duration | Start | Finish | Predecessors | Total slack | Free slack | Constraint |
| --- | --- | --- | --- | --- | --- | --- | --- | --- | --- | --- |
| 26 | 10.2 | **Phase 2 Geotech Investigation for All MSPG Design** |  | 382d | 2024-10-09 | 2026-03-26 |  | 170d |  |  |
| 27 | 10.2.1 | **Federal Access (USBR)** |  | 260d | 2024-10-09 | 2025-10-07 |  | 1617d |  |  |
| 28 | 10.2.1.1 | Right of Entry, Negotiated |  | 2mo | 2024-10-09 | 2024-12-03 | 11SS-60d | 1637d | 20d | start no earlier than 2022-12-19 |
| 29 | 10.2.1.2 | Environmental Survey, Report Prep & Clearance |  | 4mo | 2025-01-01 | 2025-04-22 | 28, 11 | 1617d | 0d |  |
| 30 | 10.2.1.3 | Cultural Survey Report Prep and Clearance |  | 4mo | 2025-01-01 | 2025-04-22 | 28, 11 | 1617d | 0d |  |
| 31 | 10.2.1.4 | Geotechnical Field Investigation and Report |  | 6mo | 2025-04-23 | 2025-10-07 | 29, 30 | 1617d |  |  |
| 32 | 10.2.2 | **Private Access** |  | 320d | 2025-01-03 | 2026-03-26 |  | 108d |  |  |
| 33 | 10.2.2.1 | Right of Entry Negotiated |  | 3mo | 2025-01-03 | 2025-03-27 | 11, 7, 8 | 168d | 60d | start no earlier than 2025-01-03 |
| 34 | 10.2.2.2 | Right of Entry Court Ordered |  | 6mo | 2025-01-03 | 2025-06-19 | 11, 7 | 108d | 0d | start no earlier than 2025-01-03 |
| 35 | 10.2.2.3 | Environmental Survey, Report Prep & Clearance |  | 4mo | 2025-06-20 | 2025-10-09 | 33, 34 | 108d | 0d |  |
| 36 | 10.2.2.4 | Cultural Survey Report Prep and Clearance |  | 4mo | 2025-06-20 | 2025-10-09 | 33, 34 | 108d | 0d |  |
| 37 | 10.2.2.5 | Geotechnical Field Investigation and Report |  | 6mo | 2025-10-10 | 2026-03-26 | 35, 36 | 108d | 0d |  |
| 38 | 10.3 | P2 Geotechnical Investigation Complete | milestone | 0d | 2026-03-26 | 2026-03-26 | 37 | 108d | 0d |  |
| 39 | 11 | **IO Tunnel and Tower Geotechnical Investigations** |  | 1455d? | 2022-10-14 | 2028-05-11 |  | 0d |  |  |
| 40 | 11.1 | P1 Geotech Investigation (30% Cutoff) | manual | 230d | 2022-10-14 | 2023-08-31 |  |  |  | start no earlier than 2022-10-14 |
| 41 | 11.2 | P2a Geotech Investigation (Dam Foundations & Grouting)(and I-O) |  | 76w | 2023-09-01 | 2025-02-13 | 40 | 0d |  | finish no later than 2025-02-13 |
| 42 | 11.3 | P2a Geotech Investigation (Roads) |  | 76w | 2023-09-01 | 2025-02-13 | 40 | 0d |  | finish no later than 2025-02-13 |
| 43 | 11.4 | **Permitting** |  | 845d? | 2025-02-14 | 2028-05-11 | 101SS | 225d |  |  |
| 44 | 11.4.1 | **Baseline Surveys and Revised ESA Consultation** |  | 845d? | 2025-02-14 | 2028-05-11 |  | 225d |  |  |
| 45 | 11.4.1.1 | Access Granted for Biological Surveys |  | 1d | 2025-02-14 | 2025-02-14 | 101SS | 1620d | 13d |  |
| 46 | 11.4.1.2 | Plant Survey 1 |  | 15d | 2025-03-17 | 2025-04-04 | 45FS+7d | 1649d | 0d | start no earlier than 2025-03-17 |
| 47 | 11.4.1.3 | Plant Survey 2 |  | 15d | 2025-05-05 | 2025-05-23 | 46FS+20d | 1649d | 0d |  |
| 48 | 11.4.1.4 | Plant Survey 3 and Report |  | 45d | 2025-06-23 | 2025-08-22 | 47FS+20d | 1649d |  |  |
| 49 | 11.4.1.5 | Land Cover Verification/Aquatic Delineation #1 |  | 15d | 2025-12-02 | 2025-12-22 | 45SS | 1413d | 0d | start no earlier than 2025-12-02 |
| 50 | 11.4.1.6 | Land Cover Verification/Aquatic Delineation #2 |  | 15d | 2026-01-13 | 2026-02-02 | 49FS+15d | 1413d | 0d |  |
| 51 | 11.4.1.7 | Land Cover Verification/Aquatic Delineation and Report |  | 45d | 2026-02-24 | 2026-04-27 | 50FS+15d | 1413d | 0d |  |
| 52 | 11.4.1.8 | Revise Impact Acers and Work with Agendas |  | 60d | 2026-04-28 | 2026-07-20 | 51 | 1413d |  |  |
| 53 | 11.4.1.9 | BUOW #1 |  | 5d | 2026-04-01 | 2026-04-07 |  | 1377d | 0d | start no earlier than 2026-04-01 |
| 54 | 11.4.1.10 | BUOW #2 |  | 5d | 2026-04-29 | 2026-05-05 | 53FS+15d | 1377d | 0d |  |
| 55 | 11.4.1.11 | BUOW #3 |  | 5d | 2026-06-03 | 2026-06-09 | 54FS+20d | 1377d | 0d |  |
| 56 | 11.4.1.12 | BUOW #4 and Report |  | 30d | 2026-07-08 | 2026-08-18 | 55FS+20d | 1377d | 267d |  |
| 57 | 11.4.1.13 | BUOW Relocation |  | 15d | 2027-08-27 | 2027-09-16 | 56 | 1110d |  | start no earlier than 2027-08-27 |
| 58 | 11.4.1.14 | SWHA #1 and TCBB #1 |  | 5d | 2026-03-02 | 2026-03-06 |  | 1387d | 0d | start no earlier than 2026-03-01 |
| 59 | 11.4.1.15 | SWHA #2 and TCBB #2 |  | 5d | 2026-03-30 | 2026-04-03 | 58FS+15d | 1387d | 0d |  |
| 60 | 11.4.1.16 | SWHA #3 and TCBB #3 |  | 5d | 2026-04-27 | 2026-05-01 | 59FS+15d | 1387d | 0d |  |
| 61 | 11.4.1.17 | SWHA #4 |  | 5d | 2026-06-01 | 2026-06-05 | 60FS+20d | 1387d | 0d |  |
| 62 | 11.4.1.18 | SWHA #5 |  | 5d | 2026-06-29 | 2026-07-03 | 61FS+15d | 1387d | 0d |  |
| 63 | 11.4.1.19 | SWHA #6 and Report |  | 30d | 2026-07-15 | 2026-08-25 | 62FS+7d | 1387d |  |  |
| 64 | 11.4.1.20 | TCBB Report |  | 30d | 2026-05-04 | 2026-06-12 | 60 | 1439d |  |  |
| 65 | 11.4.1.21 | Vernal Pool Wet Season Survey 1 |  | 10d | 2025-12-01 | 2025-12-12 | 11 | 234d | 0d | start no earlier than 2025-12-01 |
| 66 | 11.4.1.22 | Vernal Pool Wet Season Survey 2 |  | 10d | 2026-01-05 | 2026-01-16 | 65FS+15d | 234d | 0d |  |
| 67 | 11.4.1.23 | Vernal Pool Wet Season Survey 3 |  | 10d | 2026-02-09 | 2026-02-20 | 66FS+15d | 234d | 0d |  |
| 68 | 11.4.1.24 | Vernal Pool Wet Season Survey 4 (more may be needed) and Report |  | 60d | 2026-03-16 | 2026-06-05 | 67FS+15d | 234d | 90d |  |
| 69 | 11.4.1.25 | VELB Survey and Report |  | 30d | 2025-04-01 | 2025-05-12 |  | 438d | 0d | start no earlier than 2025-04-01 |
| 70 | 11.4.1.26 | VELB Transplant |  | 20d | 2025-12-09 | 2026-01-05 | 69FS+150d | 1553d |  |  |
| 71 | 11.4.1.27 | Bank Swallow Survey and Report |  | 30d | 2025-05-01 | 2025-06-11 |  | 491d | 0d | start no earlier than 2025-05-01 |
| 72 | 11.4.1.28 | CRLF Surveys and Report |  | 200d | 2026-01-05 | 2026-10-09 |  | 144d | 0d | start no earlier than 2026-01-05 |
| 73 | 11.4.1.29 | Bumble Bee Survey 1 |  | 5d | 2026-04-01 | 2026-04-07 | 69SS | 177d | 0d | start no earlier than 2026-04-01 |
| 74 | 11.4.1.30 | Bumble Bee Survey 2 |  | 5d | 2026-04-29 | 2026-05-05 | 73FS+15d | 177d | 0d |  |
| 75 | 11.4.1.31 | Bumble Bee Survey 3 |  | 5d | 2026-05-27 | 2026-06-02 | 74FS+15d | 177d | 0d |  |
| 76 | 11.4.1.32 | Bumble Bee Survey 4 and Report |  | 45d | 2026-06-24 | 2026-08-25 | 75FS+15d | 177d | 0d |  |
| 77 | 11.4.1.33 | Badger Survey and Report |  | 30d | 2025-06-12 | 2025-07-23 | 71 | 1651d | 0d |  |
| 78 | 11.4.1.34 | Bat Survey (Roosts) |  | 10d | 2025-07-24 | 2025-08-06 | 77 | 1651d | 0d |  |
| 79 | 11.4.1.35 | Bat Roosts Removal |  | 10d | 2025-08-07 | 2025-08-20 | 78 | 1651d |  |  |
| 80 | 11.4.1.36 | USFWS - Amend ESA Consultation: Prepare Report and Submit |  | 90d | 2026-10-12 | 2027-02-12 | 68, 69, 72 | 144d | 0d |  |
| 81 | 11.4.1.37 | USFWS Review and Amend ESA Permit and Take Statement |  | 120d | 2027-02-15 | 2027-07-30 | 80 | 144d | 44d |  |
| 82 | 11.4.1.38 | CDFW - Amend ESA ITP: Prepare Report and Submit |  | 90d | 2026-08-26 | 2026-12-29 | 71, 76 | 177d | 0d |  |
| 83 | 11.4.1.39 | CDFW Review Report and Ament ITP Take Statement |  | 120d | 2026-12-30 | 2027-06-15 | 82 | 177d | 0d |  |
| 84 | 11.4.1.40 | Precon Avoidance (GGS, Avian, mammal, other CEQA spp) |  | 30d | 2027-07-07 | 2027-08-17 | 83FS+15d | 1132d |  |  |

Notes:
- 40: End Date different than Jeff / Text2: P1 only gives us 30% for *all* features including roads, see below
- 41: Text2: Add critical access roads to this group
- 43: this is an aggressive schedule and best case scenario. / Text1: All permitting schedule is seasonally timed / Spranza Notes: All permitting schedule is seasonally timed
- 44: Note: Protocol surveys have required start/stop dates and conditions (rain) requirements. This schedule assumes only one year of surveys needed. 50% probability of additional year for some will be required / Text1: Assumes only 1 year of surveys needed. 50% probability some will require 2 / Spranza Notes: Assumes only 1 year of surveys needed. 50% probability some will require 2
- 45: assumes GG Dame 60% design
- 46: Protocol Survey: must start in Mar and may take more than one year of conditions (rain) does not meet protocol requirements. Agencies may also require a second year (50% prop) / Text1: Protocol Survey: Must start in Mar - Spranza / Spranza Notes: Protocol Survey: Must start in Mar - Spranza
- 47: Protocol Survey: must start in Mar and may take more than one year of conditions (rain) does not meet protocol requirements. Agencies may also require a second year (50% prop / Text1: Protocol Survey: Spranza / Spranza Notes: Protocol Survey: Spranza
- 48: Protocol Survey: must start in Mar and may take more than one year of conditions (rain) does not meet protocol requirements. Agencies may also require a second year (50% prop / Text1: Protocol Survey: Spranza / Spranza Notes: Protocol Survey: Spranza
- 49: Text1: Series starts in rainy season - December / Spranza Notes: Series starts in rainy season - December
- 52: Text1: Timing dependent on impact change and agency review time / Spranza Notes: Timing dependent on impact change and agency review time
- 53: Text1: Protocol Survey: Start April - Spranza / Spranza Notes: Protocol Survey: Start April - Spranza
- 54: Text1: Protocol Survey: Spranza / Spranza Notes: Protocol Survey: Spranza
- 55: Text1: Protocol Survey: Spranza / Spranza Notes: Protocol Survey: Spranza
- 56: Text1: Protocol Survey: Spranza / Spranza Notes: Protocol Survey: Spranza
- 57: Text1: Duration could vary depending on numbers / Spranza Notes: Duration could vary depending on numbers
- 58: Protocol Survey: Must Start in March / Text1: Protocol Survey: Must Start in March / Spranza Notes: Protocol Survey: Must Start in March
- 59: Text1: Protocol Survey: Spranza / Spranza Notes: Protocol Survey: Spranza
- 60: Text1: Protocol Survey: Spranza / Spranza Notes: Protocol Survey: Spranza
- 61: Text1: Protocol Survey: Spranza / Spranza Notes: Protocol Survey: Spranza
- 62: Text1: Protocol Survey: Spranza / Spranza Notes: Protocol Survey: Spranza
- 63: Text1: Protocol Survey: Spranza / Spranza Notes: Protocol Survey: Spranza
- 65: Protocol Survey: must start in Dec and will go through entire wet season. This survey can take more than one year if rainfall is not sufficient to meet protocol requirements. / Text1: Protocol Survey: Must start in Dec - Spranza / Spranza Notes: Protocol Survey: Must start in Dec - Spranza
- 66: Protocol Survey: must start in Dec and will go through entire wet season. This survey can take more than one year if rainfall is not sufficient to meet protocol requirements. / Text1: Protocol Survey: Spranza / Spranza Notes: Protocol Survey: Spranza
- 67: Text1: Protocol Survey: Spranza / Spranza Notes: Protocol Survey: Spranza
- 68: Protocol Survey: must start in Dec and will go through entire wet season. This survey can take more than one year if rainfall is not sufficient to meet protocol requirements. / Text1: Protocol Survey: Spranza additional may be needed / Spranza Notes: Protocol Survey: Spranza additional may be needed
- 69: Text1: Start in April recommended / Spranza Notes: Start in April recommended
- 70: Must be done from Dec-Mar - Spranza / Text1: Must be done from Dec-Mar - Spranza / Spranza Notes: Must be done from Dec-Mar - Spranza
- 71: Text1: Must start May or June / Spranza Notes: Must start May or June
- 72: Protocol Survey: must start in January / Text1: Protocol Survey: must start in January - Spranza / Spranza Notes: Protocol Survey: must start in January - Spranza
- 73: Protocol Survey: must start in April / Text1: Protocol Survey: Must begin in April - Spranza / Spranza Notes: Protocol Survey: Must begin in April - Spranza
- 74: Text1: Protocol Survey: Spranza / Spranza Notes: Protocol Survey: Spranza
- 75: Text1: Protocol Survey: Spranza / Spranza Notes: Protocol Survey: Spranza
- 76: Text1: Protocol Survey: Spranza / Spranza Notes: Protocol Survey: Spranza
- 81: Text1: Timing dependent on impact change and agency review time / Spranza Notes: Timing dependent on impact change and agency review time
- 82: Text1: Timing dependent on impact change and agency review time / Spranza Notes: Timing dependent on impact change and agency review time
- 83: Text1: Timing dependent on impact change and agency review time / Spranza Notes: Timing dependent on impact change and agency review time
- 84: Pre-con avoidance surveys for all sensative species are based on each construction area timing of impact, type of effect and could result in delay to start if species found. / Text1: Surveys based on each construction area timing / Spranza Notes: Surveys based on each construction area timing

| ID | WBS | Task | Type | Duration | Start | Finish | Predecessors | Total slack | Free slack | Constraint | Spranza Notes | Text2 |
| --- | --- | --- | --- | --- | --- | --- | --- | --- | --- | --- | --- | --- |
| 85 | 11.4.1.41 | **Compensatory Mitigation** |  | 305d | 2027-03-12 | 2028-05-11 |  |  |  |  |  |  |
| 86 | 11.4.1.41.1 | Secure LOC/Implement Mitigation Prior to Take |  | 305d | 2027-03-12 | 2028-05-11 | 82SS | 80d | 0d |  | per John Spranza & Rude discussion on Jan 3, 2023 |  |
| 87 | 11.4.1.42 | **Cultural Work** |  | 820d? | 2025-02-14 | 2028-04-06 |  | 225d |  |  |  |  |
| 88 | 11.4.1.42.1 | Prepare and Consult on Construction Phase Work Plan (per Section 106 PA) |  | 120d | 2025-02-14 | 2025-07-31 |  | 225d | 0d |  |  |  |
| 89 | 11.4.1.42.2 | Cultural Survey - with Fee Title |  | 180d | 2025-08-01 | 2026-04-09 | 88 | 225d | 0d |  |  |  |
| 90 | 11.4.1.42.3 | Testing and Evaluation of Resources |  | 180d | 2026-04-10 | 2026-12-17 | 89 | 1305d |  |  |  |  |
| 91 | 11.4.1.42.4 | Develop Treatment Plan and Implementation |  | 260d | 2026-04-10 | 2027-04-08 | 89 | 225d | 0d |  |  |  |
| 92 | 11.4.1.42.5 | Implement Avoidance/Minimization Activities During Construction |  | 260d? | 2027-04-09 | 2028-04-06 | 91 | 965d |  |  |  |  |
| 93 | 12 | **CONSTRUCTION PACKAGE #1 - RESERVOIR FACILITIES (Rev 7 10-25-22)** |  | 2165d | 2023-09-01 | 2031-12-18 |  | 0d |  |  |  |  |
| 94 | 12.1 | **Engineering - Dams** |  | 995d | 2023-09-01 | 2027-06-24 |  | 0d |  |  |  |  |
| 95 | 12.1.1 | **Inlet-Outlet Design** |  | 995d | 2023-09-01 | 2027-06-24 |  | 0d |  |  |  |  |
| 96 | 12.1.1.1 | **Inlet-Outlet Design (CP#2 - MSPG)** |  | 995d | 2023-09-01 | 2027-06-24 |  | 0d |  |  |  |  |
| 97 | 12.1.1.1.1 | Inlet-Outlet 30% Design |  | 151d | 2023-09-01 | 2024-03-29 | 40 | 0d |  | finish no later than 2024-03-29 |  | This could be considered a fixed NLT date |
| 98 | 12.1.1.1.2 | Inlet-Outlet Package Submittal | milestone | 0d | 2024-03-29 | 2024-03-29 | 97, 40 | 454d | 0d |  |  |  |
| 99 | 12.1.1.1.3 | DSOD Review of Inlet-Outlet 30% Design |  | 26w | 2024-04-01 | 2024-09-27 | 98 | 454d | 294d |  |  |  |
| 100 | 12.1.1.1.4 | Inlet-Outlet Geotech Data | milestone | 0d | 2025-02-13 | 2025-02-13 | 41 | 160d | 0d |  |  |  |
| 101 | 12.1.1.1.5 | Inlet-Outlet 60% Design |  | 39w | 2025-02-14 | 2025-11-13 | 100 | 160d | 0d |  |  | Reduce to 26 weeks |
| 102 | 12.1.1.1.6 | DSOD Review of Inlet-Outlet 60% Design |  | 26w | 2025-11-14 | 2026-05-14 | 99, 101 | 160d | 0d |  |  |  |
| 103 | 12.1.1.1.7 | Inlet-Outlet 90% Design |  | 13w | 2026-05-15 | 2026-08-13 | 102 | 160d | 0d |  |  |  |
| 104 | 12.1.1.1.8 | DSOD Review of Inlet-Outlet 90% Design |  | 26w | 2026-08-14 | 2027-02-11 | 103 | 160d | 0d |  |  |  |
| 105 | 12.1.1.1.9 | Inlet-Outlet 100% Design |  | 7w | 2027-02-12 | 2027-04-01 | 104 | 160d | 0d |  |  |  |
| 106 | 12.1.1.1.10 | DSOD Review of Inlet-Outlet 100% Design Package |  | 12w | 2027-04-02 | 2027-06-24 | 105 | 160d | 0d |  |  |  |
| 107 | 12.1.1.1.11 | Inlet-Outlet DSOD Approval Received | milestone | 0d | 2027-06-24 | 2027-06-24 | 106 | 160d | 52d |  |  | Same Date as GG Fdn Approval |
| 108 | 12.2 | **CMAR Procurement (CP#2 - MSPG)** |  | 195d | 2025-11-03 | 2026-08-03 |  | 108d |  |  |  |  |
| 109 | 12.2.1 | Award CMAR Contract | milestone | 0d | 2025-11-03 | 2025-11-03 | 238SS+37d | 108d | 0d | start no earlier than 2025-01-01 |  |  |
| 110 | 12.2.2 | Notice to Proceed |  | 6w | 2025-11-04 | 2025-12-15 | 109 | 108d | 0d |  |  |  |
| 111 | 12.2.3 | Early Submittals And Approvals - I/O and PGPs |  | 90d | 2025-12-16 | 2026-04-20 | 110 | 108d | 0d |  |  |  |
| 112 | 12.2.4 | CMAR Mobilization |  | 6mo | 2026-02-17 | 2026-08-03 | 110, 111SS+45d | 108d | 0d |  |  | Same Date as GG Fdn Approval |

Notes:
- 97: Already started? Used 200 Days instead of 457 days
- 101: Used 39 weeks instead of 78 weeks
- 103: Used 25 weeks instead of 39 weeks
- 105: Maintained 13 weeks
- 109: Jeff's Dates
- 110: Jeff's Dates

| ID | WBS | Task | Type | Duration | Start | Finish | Predecessors | Total slack | Free slack | Text2 | Text3 |
| --- | --- | --- | --- | --- | --- | --- | --- | --- | --- | --- | --- |
| 113 | 12.3 | **Roads, Bridges, Access, and Site Development** |  | 692d | 2025-02-13 | 2027-10-11 |  | 295d |  |  |  |
| 114 | 12.3.1 | Early Site Access and Staging Development |  | 100d | 2026-02-17 | 2026-07-06 | 112SS | 1423d |  |  |  |
| 115 | 12.3.2 | **Southern Construction Access Roads (Maxwell-Sites, Shoo-fly, A-1)** |  | 667d | 2025-02-13 | 2027-09-06 |  | 108d | 0d |  |  |
| 116 | 12.3.2.1 | Geotechnical Data | milestone | 0d | 2025-02-13 | 2025-02-13 | 42 | 295d | 0d | Assume P2a (Roads) |  |
| 117 | 12.3.2.2 | Final Design |  | 39w | 2025-02-14 | 2025-11-13 | 116 | 295d | 187d |  |  |
| 118 | 12.3.2.3 | Procurement and NTP |  | 90d | 2026-08-04 | 2026-12-07 | 112, 117 | 108d | 0d |  |  |
| 119 | 12.3.2.4 | Southern Construction Access Roads (Maxwell-Sites, Shoo-fly, A-1) |  | 195d | 2026-12-08 | 2027-09-06 | 118 | 108d |  |  | C1-RB3 |
| 120 | 12.3.3 | **Ancillary Roads B1, B2, C1, C2, Comm N., Comm South** |  | 692d | 2025-02-13 | 2027-10-11 |  | 1093d |  |  |  |
| 121 | 12.3.3.1 | Geotechnical Data | milestone | 0d | 2025-02-13 | 2025-02-13 | 42 | 1280d | 0d | Assume P2a (Roads) |  |
| 122 | 12.3.3.2 | Final Design |  | 39w | 2025-02-14 | 2025-11-13 | 121 | 1280d | 187d |  |  |
| 123 | 12.3.3.3 | Procurement and NTP |  | 90d | 2026-08-04 | 2026-12-07 | 112, 122 | 1093d | 0d |  |  |
| 124 | 12.3.3.4 | Ancillary Roads B1, B2, C1, C2, Comm N., Comm South |  | 220d | 2026-12-08 | 2027-10-11 | 123 | 1093d |  |  | C1-RB4 |
| 125 | 12.4 | **Inlet-Outlet Preliminary Work (CP#2 - MSPG)** |  | 100d | 2027-09-07 | 2028-01-24 |  | 108d |  |  |  |
| 126 | 12.4.1 | Inlet-Outlet Access and Staging |  | 100d | 2027-09-07 | 2028-01-24 | 107, 112, 115 | 108d | 0d | Same Date as GG Fdn Approval |  |
| 127 | 12.4.2 | Erosion and Sediment Control |  | 100d | 2027-09-07 | 2028-01-24 | 126SS | 108d | 0d |  |  |
| 128 | 12.4.3 | Clearing / Grubbing Topsoil Salvage from Work Areas |  | 100d | 2027-09-07 | 2028-01-24 | 126SS | 108d | 0d |  |  |
| 129 | 12.4.4 | Demolition |  | 50d | 2027-09-21 | 2027-11-29 | 126SS+10d | 148d | 40d |  |  |
| 130 | 12.5 | **Inlet Outlet Facilities (CP#2 - MSPG)** |  | 1018d | 2028-01-25 | 2031-12-18 |  | 0d |  |  |  |
| 131 | 12.5.1 | **Develop Downstream Portal** |  | 80d | 2028-01-25 | 2028-05-15 |  | 108d |  |  |  |
| 132 | 12.5.1.1 | Downstream Portal Excavation |  | 80d | 2028-01-25 | 2028-05-15 | 107, 112, 126, 127, 128, 129 | 108d | 0d |  |  |
| 133 | 12.5.1.2 | Downstream Portal Rock Bolting |  | 80d | 2028-01-25 | 2028-05-15 | 132SS | 108d | 0d |  |  |
| 134 | 12.5.2 | **Develop Upstream Portal** |  | 185d | 2028-01-25 | 2028-10-09 |  | 303d |  |  |  |
| 135 | 12.5.2.1 | Intake Channel Excavation |  | 60d | 2028-01-25 | 2028-04-17 | 107, 112, 126 | 303d | 0d |  |  |
| 136 | 12.5.2.2 | Upstream Portal Excavation |  | 125d | 2028-04-18 | 2028-10-09 | 135 | 303d | 0d |  |  |
| 137 | 12.5.2.3 | Upstream Portal Rock Bolting |  | 125d | 2028-04-18 | 2028-10-09 | 136SS | 303d | 195d |  |  |

| ID | WBS | Task | Type | Duration | Start | Finish | Predecessors | Total slack | Free slack | Constraint | Text2 |
| --- | --- | --- | --- | --- | --- | --- | --- | --- | --- | --- | --- |
| 138 | 12.5.3 | **Tunnels Excavation and Lining (Double Shift)** |  | 480d | 2028-05-16 | 2030-03-18 |  | 108d |  |  |  |
| 139 | 12.5.3.1 | Tunnel Excavation - Double Shift |  | 300d | 2028-05-16 | 2029-07-09 | 133 | 108d | 0d |  |  |
| 140 | 12.5.3.2 | Tunnel Lining |  | 180d | 2029-07-10 | 2030-03-18 | 139 | 368d | 230d |  |  |
| 141 | 12.5.4 | **Intake and Outlet Structures** |  | 638d | 2029-07-10 | 2031-12-18 |  | 0d |  |  |  |
| 142 | 12.5.4.1 | Intake Structure Foundation |  | 60d | 2029-07-10 | 2029-10-01 | 137, 139 | 108d | 0d |  |  |
| 143 | 12.5.4.2 | Intake Structure Concrete |  | 200d | 2029-10-02 | 2030-07-08 | 142 | 108d | 0d |  |  |
| 144 | 12.5.4.3 | Intake Structure Gates and Mechanical |  | 90d | 2030-07-09 | 2030-11-11 | 142, 143 | 108d | 0d |  |  |
| 145 | 12.5.4.4 | I/O Completion and Restoration |  | 60d | 2030-11-12 | 2031-02-03 | 143, 144 | 108d | 0d |  |  |
| 146 | 12.5.4.5 | Inlet-Outlet Ready for Commissioning | milestone | 0d | 2031-02-03 | 2031-02-03 | 140, 145 | 138d |  |  |  |
| 147 | 12.5.4.6 | Inlet-Outlet Startup and Commissioning |  | 90d | 2031-08-15 | 2031-12-18 | 146, 266 | 0d |  |  |  |
| 148 | 12.5.4.7 | Inlet-Outlet Completion | milestone | 0d | 2031-12-18 | 2031-12-18 | 147 | 0d |  |  | One Month after Dams Project C1 |
| 149 | 13 | **CONSTRUCTION PACKAGE #2 - MSPG FACILITIES** |  | 2477d | 2022-06-22 | 2031-12-18 |  | 0d |  |  |  |
| 150 | 13.1 | **POWER INTERCONNECTION (CAISO / PG&E DESIGN AND CONSTRUCTION)** |  | 2192d | 2022-06-22 | 2030-11-14 |  | 0d |  |  |  |
| 151 | 13.1.1 | **Prepare & Submit CAISO Package** |  | 213d | 2022-06-22 | 2023-04-14 |  | 0d |  |  |  |
| 152 | 13.1.1.1 | Prepare Pump/Motor Package for Vendors to obtain Data |  | 10d | 2023-01-03 | 2023-01-16 |  | 2298d | 0d | start no earlier than 2023-01-03 |  |
| 153 | 13.1.1.2 | Pump Vendors Prepare & Send Data |  | 30d | 2023-01-17 | 2023-02-27 | 152 | 2298d |  |  |  |
| 154 | 13.1.1.3 | Prepare Hydropower Generator/Turbine Package for Vendors to Obtain Data |  | 40d | 2022-06-22 | 2022-08-16 |  | 0d |  | finish no earlier than 2022-08-16 |  |
| 155 | 13.1.1.4 | Generator/Turbine Vendors Prepare & Send Data |  | 100d | 2022-08-17 | 2023-01-03 | 154 | 0d |  |  |  |
| 156 | 13.1.1.5 | HC Engineering Team provide info to ZGlobal |  | 15d | 2023-01-04 | 2023-01-24 | 155 | 0d |  |  |  |
| 157 | 13.1.1.6 | ZGlobal run models and prepare CAISO package |  | 20d | 2023-01-25 | 2023-02-21 | 156 | 0d |  |  |  |
| 158 | 13.1.1.7 | Sites Review CAISO Package & Approve |  | 20d | 2023-02-22 | 2023-03-21 | 157 | 0d |  |  |  |
| 159 | 13.1.1.8 | Zglobal Submit CAISO Package & Sites Submit $500k in Fees |  | 18d | 2023-03-22 | 2023-04-14 | 158 | 0d |  |  |  |
| 160 | 13.1.2 | **Respond to CAISO** |  | 874d | 2023-04-17 | 2026-08-20 |  | 0d |  |  |  |
| 161 | 13.1.2.1 | Scoping Meeting |  | 21d | 2023-04-17 | 2023-05-15 | 159 | 0d |  |  |  |
| 162 | 13.1.2.2 | Phase 1 Study |  | 328d | 2023-05-16 | 2024-08-15 | 161 | 0d |  |  |  |
| 163 | 13.1.2.3 | Phase 1 Results Meeting |  | 283d | 2023-08-16 | 2024-09-13 | 161FS+66d | 1739d | 0d |  |  |
| 164 | 13.1.2.4 | First Finanical Security Posting |  | 106d | 2024-08-16 | 2025-01-10 | 162 | 0d |  |  |  |
| 165 | 13.1.2.5 | Phase II Study |  | 226d | 2025-01-13 | 2025-11-24 | 164 | 0d |  |  |  |
| 166 | 13.1.2.6 | Phase II Results Meeting |  | 22d | 2025-11-25 | 2025-12-24 | 165 | 1561d |  |  |  |
| 167 | 13.1.2.7 | Transmission Plan Deliverability (Resource Adequacy Process) |  | 10d | 2025-11-25 | 2025-12-08 | 165 | 0d |  |  |  |
| 168 | 13.1.2.8 | Second Financial Security Posting |  | 31d | 2026-03-23 | 2026-05-04 | 167FS+74d | 0d |  |  |  |
| 169 | 13.1.2.9 | Draft Impact Analysis Issues |  | 23d | 2026-05-05 | 2026-06-04 | 168 | 1445d |  |  |  |
| 170 | 13.1.2.10 | Reassessment Results |  | 78d | 2026-05-05 | 2026-08-20 | 168 | 1390d |  |  |  |
| 171 | 13.1.2.11 | Receive Draft Interconnection Agreement from CAISO |  | 23d | 2026-05-29 | 2026-06-30 | 168FS+18d | 0d |  |  |  |
| 172 | 13.1.2.12 | Negotiate Interconnection Agreement |  | 37d | 2026-07-01 | 2026-08-20 | 171 | 0d |  |  |  |

| ID | WBS | Task | Duration | Start | Finish | Predecessors | Baseline start | Baseline finish | Baseline duration | Total slack | Free slack | Constraint | Text1 |
| --- | --- | --- | --- | --- | --- | --- | --- | --- | --- | --- | --- | --- | --- |
| 173 | 13.1.3 | **PG&E Point of Interconnection Substation** | 1944d | 2023-06-05 | 2030-11-14 |  |  |  |  | 285d |  |  |  |
| 174 | 13.1.3.1 | **Engineering** | 1099d | 2023-06-05 | 2027-08-19 |  |  |  |  | 839d |  |  |  |
| 175 | 13.1.3.1.1 | Preliminary Design 30% (by HC) | 130d | 2023-06-05 | 2023-12-01 |  |  |  |  | 1999d | 0d | finish no earlier than 2023-12-01 |  |
| 176 | 13.1.3.1.2 | Class 3 Cost Estimate (by HC) | 100d | 2023-12-04 | 2024-04-19 | 175 |  |  |  | 1999d |  | start no earlier than 2023-12-04 |  |
| 177 | 13.1.3.1.3 | Establish E&P Agreement with PG&E | 30d | 2024-09-16 | 2024-10-25 | 163 |  |  |  | 1739d | 0d |  |  |
| 178 | 13.1.3.1.4 | Preliminary Design 30% - by PG&E | 125d | 2024-10-28 | 2025-04-18 | 177 |  |  |  | 1739d |  | start no earlier than 2022-10-03 |  |
| 179 | 13.1.3.1.5 | Final 60%, 90%, 100% Design - by PG&E | 260d | 2026-08-21 | 2027-08-19 | 172 |  |  |  | 0d |  |  |  |
| 180 | 13.1.3.2 | **Construction - by PG&E** | 785d | 2027-08-20 | 2030-08-22 |  |  |  |  | 0d |  |  |  |
| 181 | 13.1.3.2.1 | Procure Equipment | 260d | 2027-08-20 | 2028-08-17 | 179 |  |  |  | 0d |  |  |  |
| 182 | 13.1.3.2.2 | Construction | 525d | 2028-08-18 | 2030-08-22 | 181 |  |  |  | 0d |  |  |  |
| 183 | 13.1.3.3 | **Commissioning** | 60d | 2030-08-23 | 2030-11-14 |  |  |  |  | 0d |  |  |  |
| 184 | 13.1.3.3.1 | Commission | 60d | 2030-08-23 | 2030-11-14 | 182 |  |  |  | 0d |  |  |  |
| 185 | 3 | **Funks/TRR Pipelines (DSOD Jurisdictional)** | 1779d | 2023-01-09 | 2029-11-01 |  |  |  |  | 555d |  |  |  |
| 186 | 3.3.1 | **Engineering** | 1069d | 2023-01-09 | 2027-02-11 |  |  |  |  | 1039d |  |  |  |
| 187 | 3.3.1 | Preliminary (30%) | 235d | 2023-01-09 | 2023-12-01 |  | 2022-06-01 | 2023-05-16 | 250d | 1999d | 0d | start no earlier than 2023-01-09 | HC-FTP-100 |
| 188 | 13.2.1.2 | Class 3 Cost Estimate | 100d | 2023-12-04 | 2024-04-19 | 187 |  |  |  | 1999d |  |  |  |
| 189 | 3.3.1 | Final 60% Design | 180d | 2025-09-12 | 2026-05-21 | 11, 38FS-140d | 2023-05-17 | 2024-07-09 | 300d | 340d | 0d |  | HC-FTP-110 |
| 190 | 13.2.1.4 | Final 90% Design | 120d | 2026-05-22 | 2026-11-05 | 189 |  |  |  | 340d | 0d |  |  |
| 191 | 4.4.1 | Final 100% Design | 70d | 2026-11-06 | 2027-02-11 | 190 | 2023-06-14 | 2024-10-15 | 350d | 340d | 0d |  | HC-TPL-110 |
| 192 | 3.3.3 | **Construction** | 680d | 2027-02-12 | 2029-09-20 |  |  |  |  | 340d |  |  |  |
| 193 | 3.3.3 | Submittals | 90d | 2027-02-12 | 2027-06-17 | 191 | 2024-11-13 | 2025-02-04 | 60d | 340d | 95d |  | HC-FTP-300 |
| 194 | 13.2.2.2 | **Field Construction** | 450d | 2027-10-29 | 2029-07-19 | 81, 83, 86FS-140d, 91 |  |  |  | 245d |  |  |  |
| 195 | 3.3.3 | Structures | 330d | 2027-10-29 | 2029-02-01 | 193 | 2025-02-05 | 2026-05-12 | 330d | 675d | 120d |  | HC-FTP-310 |
| 196 | 3.3.3 | Pipelines | 450d | 2027-10-29 | 2029-07-19 | 193 | 2025-02-05 | 2026-08-18 | 400d | 245d | 0d |  | HC-FTP-320 |
| 197 | 3.3.3 | Pipelines in Reservoir | 250d | 2028-06-16 | 2029-05-31 | 193, 230 | 2025-02-05 | 2026-08-18 | 400d | 80d | 0d |  | HC-FTP-320 |
| 198 | 3.3.3 | Testing | 45d | 2029-07-20 | 2029-09-20 | 195, 196, 197 | 2026-08-19 | 2026-10-20 | 45d | 555d | 0d |  | HC-FTP-330 |

| ID | WBS | Task | Duration | Start | Finish | Predecessors | Baseline start | Baseline finish | Baseline duration | Total slack | Free slack | Constraint | Text1 |
| --- | --- | --- | --- | --- | --- | --- | --- | --- | --- | --- | --- | --- | --- |
| 199 | 3.3.4 | **Commissioning** | 30d | 2029-09-21 | 2029-11-01 |  |  |  |  | 555d |  |  |  |
| 200 | 3.3.4 | Commission | 30d | 2029-09-21 | 2029-11-01 | 198 | 2026-10-21 | 2026-12-01 | 30d | 555d |  |  | HC-FTP-400 |
| 201 | 4 | **Transmission Powerlines** | 2021d | 2023-06-01 | 2031-02-27 |  |  |  |  | 210d |  |  |  |
| 202 | 4.4.1 | **Engineering** | 996d | 2023-06-01 | 2027-03-25 |  |  |  |  | 886d |  |  |  |
| 203 | 4.4.1 | Preliminary (30%) | 150d | 2023-06-01 | 2023-12-27 |  | 2022-06-01 | 2023-06-13 | 270d | 1981d | 0d | start no earlier than 2023-06-01 | HC-TPL-100 |
| 204 | 13.3.1.2 | Class 3 Cost Estimate | 100d | 2023-12-28 | 2024-05-15 | 203 |  |  |  | 1981d |  |  |  |
| 205 | 5.5.1 | Final 60% Design | 180d | 2025-09-12 | 2026-05-21 | 11, 38FS-140d | 2023-06-14 | 2024-10-15 | 350d | 290d | 0d |  | HC-FRV-110 |
| 206 | 13.3.1.4 | Final 90% Design | 150d | 2026-05-22 | 2026-12-17 | 205 |  |  |  | 290d | 0d |  |  |
| 207 | 4.4.1 | Final 100% Design | 70d | 2026-12-18 | 2027-03-25 | 206 | 2023-06-14 | 2024-10-15 | 350d | 290d | 0d |  | HC-TPL-110 |
| 208 | 4.4.3 | **Construction** | 995d | 2027-03-26 | 2031-01-16 |  |  |  |  | 0d |  |  |  |
| 209 | 4.4.3 | Submittals | 60d | 2027-03-26 | 2027-06-17 | 207, 240 | 2025-02-19 | 2025-05-13 | 60d | 290d | 95d |  | HC-TPL-300 |
| 210 | 13.3.2.2 | **Field Construction** | 715d | 2027-10-29 | 2030-07-25 | 81, 83, 86FS-140d, 91 |  |  |  | 80d |  |  |  |
| 211 | 4.4.3 | Procurement | 300d | 2027-10-29 | 2028-12-21 | 209 | 2025-05-14 | 2026-07-07 | 300d | 195d | 0d |  | HC-TPL-310 |
| 212 | 4.4.3 | Towers/Powerlines to POI | 175d | 2028-12-22 | 2029-08-23 | 209, 211 | 2026-07-08 | 2027-08-31 | 300d | 320d |  |  | HC-TPL-320 |
| 213 | 4.4.3 | Towers/Powerlines Funks/TRR | 300d | 2029-06-01 | 2030-07-25 | 196SS+250d, 211, 197SS+250d | 2026-08-19 | 2027-11-23 | 330d | 80d |  |  | HC-TPL-330 |
| 214 | 4.4.3 | Testing | 45d | 2030-11-15 | 2031-01-16 | 211, 212, 213, 184 | 2027-11-24 | 2028-01-25 | 45d | 0d |  |  | HC-TPL-340 |
| 215 | 4.4.4 | **Commissioning** | 30d | 2031-01-17 | 2031-02-27 |  |  |  |  | 0d |  |  |  |
| 216 | 4.4.4 | Commission | 30d | 2031-01-17 | 2031-02-27 | 214 | 2028-01-26 | 2028-03-07 | 30d | 0d |  |  | HC-TPL-400 |
| 217 | 5 | **Funks Reservoir** | 2226d | 2023-01-09 | 2031-07-21 |  |  |  |  | 108d |  |  |  |
| 218 | 5.5.1 | **Engineering** | 1099d | 2023-01-09 | 2027-03-25 |  |  |  |  | 814d |  |  |  |
| 219 | 5.5.1 | Preliminary Design (30%) | 235d | 2023-01-09 | 2023-12-01 |  | 2022-06-01 | 2023-06-13 | 270d | 1999d | 0d | start no earlier than 2023-01-09 | HC-FRV-100 |
| 220 | 13.4.1.2 | Class 3 Cost Estimate | 100d | 2023-12-04 | 2024-04-19 | 219 |  |  |  | 1999d |  |  |  |
| 221 | 5.5.1 | Final 60% Design | 180d | 2025-09-12 | 2026-05-21 | 11, 38FS-140d | 2023-06-14 | 2024-10-15 | 350d | 115d | 0d |  | HC-FRV-110 |
| 222 | 13.4.1.4 | Final 90% Design | 130d | 2026-05-22 | 2026-11-19 | 221 |  |  |  | 115d | 0d |  |  |
| 223 | 13.4.1.5 | Final 100% Design | 90d | 2026-11-20 | 2027-03-25 | 222 |  |  |  | 115d | 0d |  |  |

| ID | WBS | Task | Duration | Start | Finish | Predecessors | Baseline start | Baseline finish | Baseline duration | Total slack | Free slack | Constraint | Text1 |
| --- | --- | --- | --- | --- | --- | --- | --- | --- | --- | --- | --- | --- | --- |
| 224 | 5.5.3 | **Construction** | 1127d | 2027-03-26 | 2031-07-21 |  |  |  |  | 108d |  |  |  |
| 225 | 5.5.3 | Submittals | 120d | 2027-03-26 | 2027-09-09 | 223 | 2025-02-19 | 2025-08-05 | 120d | 115d | 35d |  | HC-FRV-300 |
| 226 | 13.4.2.2 | **Field Construction** | 972d | 2027-10-29 | 2031-07-21 | 81, 83, 86FS-140d, 91 |  |  |  | 80d |  |  |  |
| 227 | 5.5.3 | Haulroads | 200d | 2027-10-29 | 2028-08-03 | 225 | 2025-08-06 | 2026-05-12 | 200d | 80d | 0d |  | HC-FRV-310 |
| 228 | 5.5.3 | Initial Sediment Removal | 400d | 2028-02-18 | 2029-08-30 | 225, 227SS+80d | 2025-08-06 | 2026-07-21 | 250d | 600d |  |  | HC-FRV-320 |
| 229 | 5.5.3 | PGP Cofferdams (build) | 85d | 2028-02-18 | 2028-06-15 | 225, 227SS+80d | 2026-07-22 | 2027-07-06 | 250d | 125d | 0d | start no earlier than 2025-12-01 | HC-FRV-330 |
| 230 | 5.5.3 | Pipeline Cofferdams (build) | 85d | 2028-02-18 | 2028-06-15 | 225, 227SS+80d | 2026-07-22 | 2027-07-06 | 250d | 80d | 0d | start no earlier than 2026-12-01 | HC-FRV-330 |
| 231 | 13.4.2.2.5 | Final Sediment Removal (After I/O and Golden Gate Dam nearly complete) | 120d | 2031-02-04 | 2031-07-21 | 145 |  |  |  | 108d |  |  |  |
| 232 | 5.5.4 | **Commissioning** | 30d | 2028-06-16 | 2028-07-27 |  |  |  |  | 885d |  |  |  |
| 233 | 5.5.4 | Commission | 30d | 2028-06-16 | 2028-07-27 | 230 | 2027-09-29 | 2027-11-09 | 30d | 885d |  |  | HC-FRV-400 |
| 234 | 6 | **Funks Pumping Generating Plant** | 2334d | 2023-01-09 | 2031-12-18 |  |  |  |  | 0d |  |  |  |
| 235 | 6.6.1 | **Engineering** | 1099d | 2023-01-09 | 2027-03-25 |  |  |  |  | 807d |  |  |  |
| 236 | 6.6.1 | Preliminary (30%) | 235d | 2023-01-09 | 2023-12-01 |  | 2022-06-01 | 2023-06-13 | 270d | 1999d | 0d | start no earlier than 2023-01-09 | HC-FPG-100 |
| 237 | 13.5.1.2 | Class 3 Cost Estimate | 100d | 2023-12-04 | 2024-04-19 | 236 |  |  |  | 1999d |  |  |  |
| 238 | 5.5.1 | Final 60% Design | 180d | 2025-09-12 | 2026-05-21 | 11, 38FS-140d | 2023-06-14 | 2024-10-15 | 350d | 108d | 0d |  | HC-FRV-110 |
| 239 | 13.5.1.4 | Final 90% Design | 150d | 2026-05-22 | 2026-12-17 | 238 |  |  |  | 290d | 0d |  |  |
| 240 | 4.4.1 | Final 100% Design | 70d | 2026-12-18 | 2027-03-25 | 239 | 2023-06-14 | 2024-10-15 | 350d | 290d | 0d |  | HC-TPL-110 |
| 241 | 6.6.3 | **Construction** | 1205d | 2027-03-26 | 2031-11-06 |  |  |  |  | 30d |  |  |  |
| 242 | 6.6.3 | Submittals | 120d | 2027-03-26 | 2027-09-09 | 240 | 2025-02-19 | 2025-08-05 | 120d | 325d | 0d |  | HC-FPG-300 |
| 243 | 13.5.2.2 | **Field Construction** | 865d | 2027-10-29 | 2031-02-20 | 81, 83, 86FS-140d, 91 |  |  |  | 215d |  |  |  |
| 244 | 6.6.3 | Large Equipment Procurement | 350d | 2027-10-29 | 2029-03-01 | 242 | 2025-08-06 | 2026-12-08 | 350d | 730d |  |  | HC-FPG-310 |
| 245 | 9.9.3 | Pump Generating Plant Structure | 700d | 2028-06-16 | 2031-02-20 | 242, 229 | 2026-05-27 | 2027-07-20 | 300d | 125d |  |  | HC-SUB-320 |
| 246 | 13.5.2.2.3 | Turbine Structure | 330d | 2027-12-03 | 2029-03-08 | 242FS+60d |  |  |  | 635d |  |  |  |
| 247 | 13.5.2.2.4 | Energy Dissipation Valve Structure | 265d | 2028-02-25 | 2029-03-01 | 242FS+120d |  |  |  | 640d |  |  |  |
| 248 | 13.5.2.2.5 | Electrical Building | 265d | 2028-05-19 | 2029-05-24 | 242FS+180d |  |  |  | 580d |  |  |  |
| 249 | 13.5.2.2.6 | Site Electrical and PGP Sitework | 450d | 2027-10-29 | 2029-07-19 | 242 |  |  |  | 540d |  |  |  |
| 250 | 6.6.3 | Testing | 60d | 2031-08-15 | 2031-11-06 | 249, 245, 246, 248, 247, 214, 266 | 2028-04-12 | 2028-07-04 | 60d | 0d |  |  | HC-FPG-330 |

| ID | WBS | Task | Duration | Start | Finish | Predecessors | Baseline start | Baseline finish | Baseline duration | Total slack | Free slack | Constraint | Text1 |
| --- | --- | --- | --- | --- | --- | --- | --- | --- | --- | --- | --- | --- | --- |
| 251 | 6.6.4 | **Commissioning** | 30d | 2031-11-07 | 2031-12-18 |  |  |  |  | 0d |  |  |  |
| 252 | 6.6.4 | Commission | 30d | 2031-11-07 | 2031-12-18 | 250 | 2028-07-05 | 2028-08-15 | 30d | 0d |  |  | HC-FPG-400 |
| 253 | 13.6 | **Funks Substation** | 2244d | 2023-01-09 | 2031-08-14 |  |  |  |  | 90d |  |  |  |
| 254 | 13.6.1 | **Engineering (Excludes PG&E]** | 1229d | 2023-01-09 | 2027-09-23 |  |  |  |  | 1105d |  |  |  |
| 255 | 13.6.1.1 | Design 30% | 235d | 2023-01-09 | 2023-12-01 | 159FF+30d |  |  |  | 2059d | 0d | start no earlier than 2023-01-09 |  |
| 256 | 13.6.1.2 | Class 3 Cost Estimate | 40d | 2023-12-04 | 2024-01-26 | 255 |  |  |  | 2059d |  |  |  |
| 257 | 13.6.1.3 | Final 60% Design | 220d | 2025-09-12 | 2026-07-16 | 11, 38FS-140d |  |  |  | 495d | 0d |  |  |
| 258 | 13.6.1.4 | Final 90% Design | 180d | 2026-07-17 | 2027-03-25 | 257 |  |  |  | 495d | 0d |  |  |
| 259 | 13.6.1.5 | Final 100% Design | 130d | 2027-03-26 | 2027-09-23 | 258 |  |  |  | 495d | 0d |  |  |
| 260 | 13.6.2 | **Construction** | 400d | 2027-09-24 | 2029-04-05 |  |  |  |  | 495d |  |  |  |
| 261 | 9.9.3 | Submittals | 100d | 2027-09-24 | 2028-02-10 | 259 | 2025-12-10 | 2026-05-26 | 120d | 495d | 0d |  | HC-SUB-300 |
| 262 | 13.6.2.2 | **Field Construction** | 300d | 2028-02-11 | 2029-04-05 | 81, 83, 86FS-140d, 91 |  |  |  | 495d |  |  |  |
| 263 | 13.6.2.2.1 | Earthwork/Pad Prep | 150d | 2028-02-11 | 2028-09-07 | 261 |  |  |  | 495d | 0d |  |  |
| 264 | 9.9.3 | Large Equipment Procurement | 150d | 2028-02-11 | 2028-09-07 | 261 | 2026-05-27 | 2027-05-11 | 250d | 645d |  |  | HC-SUB-310 |
| 265 | 13.6.2.2.3 | Breaker Substation | 150d | 2028-09-08 | 2029-04-05 | 263 |  |  |  | 495d |  |  |  |
| 266 | 13.6.3 | Commissioning | 120d | 2031-02-28 | 2031-08-14 | 260, 216 |  |  |  | 0d |  |  |  |
| 267 | 7 | **TRR West Reservoir** | 1918d | 2023-01-09 | 2030-05-15 |  |  |  |  | 416d |  |  |  |
| 268 | 7.7.1 | **Engineering** | 1158d | 2023-01-09 | 2027-06-16 |  |  |  |  | 1176d |  |  |  |
| 269 | 7.7.1 | Preliminary (30%) | 235d | 2023-01-09 | 2023-12-01 |  | 2022-06-01 | 2023-06-13 | 270d | 1999d | 0d | start no earlier than 2023-01-09 | HC-TER-100 |
| 270 | 13.7.1.2 | Class 3 Cost Estimate | 100d | 2023-12-04 | 2024-04-19 | 269 |  |  |  | 1999d |  |  |  |
| 271 | 13.7.1.3 | Final 60% Design | 130d | 2026-01-01 | 2026-07-01 | 11, 38FS-140d |  |  |  | 416d | 0d | finish no earlier than 2026-07-01 |  |
| 272 | 13.7.1.4 | Final 90% Design | 150d | 2026-07-02 | 2027-01-27 | 271 |  |  |  | 416d | 0d |  |  |
| 273 | 7.7.1 | Final 100% Design | 100d | 2027-01-28 | 2027-06-16 | 272 | 2023-06-14 | 2024-10-15 | 350d | 416d | 0d |  | HC-TER-110 |
| 274 | 7.7.3 | **Construction** | 730d | 2027-06-17 | 2030-04-03 |  |  |  |  | 416d |  |  |  |
| 275 | 7.7.3 | Submittals | 120d | 2027-06-17 | 2027-12-01 | 273 | 2025-02-19 | 2025-08-05 | 120d | 416d | 0d |  | HC-TER-300 |

| ID | WBS | Task | Duration | Start | Finish | Predecessors | Baseline start | Baseline finish | Baseline duration | Total slack | Free slack | Constraint | Text1 |
| --- | --- | --- | --- | --- | --- | --- | --- | --- | --- | --- | --- | --- | --- |
| 276 | 13.7.2.2 | **Field Construction** | 550d | 2027-12-02 | 2030-01-09 | 81, 83, 86FS-140d, 91 |  |  |  | 416d |  |  |  |
| 277 | 7.7.3 | Haulroads | 200d | 2027-12-02 | 2028-09-06 | 275 | 2025-08-06 | 2026-05-12 | 200d | 416d | 0d |  | HC-TER-310 |
| 278 | 7.7.3 | Earthwork/Structures | 300d | 2028-09-07 | 2029-10-31 | 277 | 2026-07-22 | 2027-09-14 | 300d | 416d | 0d |  | HC-TER-330 |
| 279 | 7.7.3 | Subgrade and Liner | 200d | 2029-04-05 | 2030-01-09 | 278FS-1200h | 2027-02-17 | 2027-11-23 | 200d | 416d | 0d |  | HC-TER-340 |
| 280 | 7.7.3 | Testing | 60d | 2030-01-10 | 2030-04-03 | 278, 279 | 2027-11-24 | 2028-02-15 | 60d | 416d | 0d |  | HC-TER-350 |
| 281 | 7.7.4 | **Commissioning** | 30d | 2030-04-04 | 2030-05-15 |  |  |  |  | 416d |  |  |  |
| 282 | 7.7.4 | Commission | 30d | 2030-04-04 | 2030-05-15 | 280 | 2028-02-16 | 2028-03-28 | 30d | 416d |  |  | HC-TER-400 |
| 283 | 8 | **TRR West Pumping Generating Plant** | 2334d | 2023-01-09 | 2031-12-18 |  |  |  |  | 0d |  |  |  |
| 284 | 8.8.1 | **Engineering** | 1099d | 2023-01-09 | 2027-03-25 |  |  |  |  | 1024d |  |  |  |
| 285 | 8.8.1 | Preliminary (30%) | 235d | 2023-01-09 | 2023-12-01 |  | 2022-06-01 | 2023-06-13 | 270d | 1999d | 0d | start no earlier than 2023-01-09 | HC-TPG-100 |
| 286 | 13.8.1.2 | Class 3 Cost Estimate | 100d | 2023-12-04 | 2024-04-19 | 285 |  |  |  | 1999d |  |  |  |
| 287 | 5.5.1 | Final 60% Design | 180d | 2025-09-12 | 2026-05-21 | 11, 38FS-140d | 2023-06-14 | 2024-10-15 | 350d | 325d | 0d |  | HC-FRV-110 |
| 288 | 13.8.1.4 | Final 90% Design | 150d | 2026-05-22 | 2026-12-17 | 287 |  |  |  | 325d | 0d |  |  |
| 289 | 4.4.1 | Final 100% Design | 70d | 2026-12-18 | 2027-03-25 | 288 | 2023-06-14 | 2024-10-15 | 350d | 325d | 0d |  | HC-TPL-110 |
| 290 | 8.8.3 | **Construction** | 1205d | 2027-03-26 | 2031-11-06 |  |  |  |  | 30d |  |  |  |
| 291 | 8.8.3 | Submittals | 120d | 2027-03-26 | 2027-09-09 | 289, 321 | 2025-02-19 | 2025-08-05 | 120d | 325d | 0d |  | HC-TPG-300 |
| 292 | 8.8.3 | Large Equipment Procurement | 355d | 2027-09-10 | 2029-01-18 | 291 | 2025-08-06 | 2026-12-15 | 355d | 760d |  | start no earlier than 2022-10-10 | HC-TPG-310 |
| 293 | 13.8.2.3 | **Field Construction** | 700d | 2027-10-29 | 2030-07-04 | 81, 83, 86FS-140d, 91 |  |  |  | 290d |  |  |  |
| 294 | 9.9.3 | Pump Generating Plant Structure | 700d | 2027-10-29 | 2030-07-04 | 291 | 2026-05-27 | 2027-07-20 | 300d | 290d |  |  | HC-SUB-320 |
| 295 | 13.8.2.3.2 | Turbine Structure | 330d | 2027-12-03 | 2029-03-08 | 291FS+60d |  |  |  | 635d |  |  |  |
| 296 | 13.8.2.3.3 | Energy Dissipation Valve Structure | 265d | 2028-02-25 | 2029-03-01 | 291FS+120d |  |  |  | 640d |  |  |  |
| 297 | 13.8.2.3.4 | Electrical Building | 265d | 2028-05-19 | 2029-05-24 | 291FS+180d |  |  |  | 580d |  |  |  |
| 298 | 13.8.2.3.5 | Site Electrical and PGP Sitework | 450d | 2027-10-29 | 2029-07-19 | 291 |  |  |  | 540d |  |  |  |
| 299 | 8.8.3 | Testing | 60d | 2031-08-15 | 2031-11-06 | 214, 297, 294, 295, 296, 298, 314 | 2028-04-12 | 2028-07-04 | 60d | 0d |  |  | HC-TPG-330 |

| ID | WBS | Task | Duration | Start | Finish | Predecessors | Baseline start | Baseline finish | Baseline duration | Total slack | Free slack | Constraint | Text1 |
| --- | --- | --- | --- | --- | --- | --- | --- | --- | --- | --- | --- | --- | --- |
| 300 | 8.8.4 | **Commissioning** | 30d | 2031-11-07 | 2031-12-18 |  |  |  |  | 0d |  |  |  |
| 301 | 8.8.4 | Commission | 30d | 2031-11-07 | 2031-12-18 | 299 | 2028-07-05 | 2028-08-15 | 30d | 0d |  |  | HC-TPG-400 |
| 302 | 9 | **TRR West Substation** | 2244d | 2023-01-09 | 2031-08-14 |  |  |  |  | 90d |  |  |  |
| 303 | 9.9.1 | **Engineering [excludes PG&E]** | 1229d | 2023-01-09 | 2027-09-23 |  |  |  |  | 1004d |  |  |  |
| 304 | 9.9.1 | Preliminary (30%) | 235d | 2023-01-09 | 2023-12-01 | 159FF+30d | 2022-06-01 | 2023-06-13 | 270d | 2059d | 0d | start no earlier than 2023-01-09 | HC-SUB-100 |
| 305 | 13.9.1.2 | Class 3 Cost Estimate | 40d | 2023-12-04 | 2024-01-26 | 304 |  |  |  | 2059d |  |  |  |
| 306 | 9.9.1 | Design (60%, 90%, 100%) | 530d | 2025-09-12 | 2027-09-23 | 11, 38FS-140d | 2023-06-14 | 2024-10-15 | 350d | 305d | 0d |  | HC-SUB-110 |
| 307 | 9.9.3 | **Construction** | 500d | 2028-01-28 | 2029-12-27 |  |  |  |  | 305d |  |  |  |
| 308 | 9.9.3 | Submittals | 100d | 2028-01-28 | 2028-06-15 | 306FS+90d | 2025-12-10 | 2026-05-26 | 120d | 305d | 0d |  | HC-SUB-300 |
| 309 | 13.9.2.2 | **Field Construction** | 400d | 2028-06-16 | 2029-12-27 | 81, 83, 86FS-140d, 91 |  |  |  | 305d |  |  |  |
| 310 | 13.9.2.2.1 | Earthwork/Pad Prep | 150d | 2028-06-16 | 2029-01-11 | 308 |  |  |  | 555d |  |  |  |
| 311 | 9.9.3 | Large Equipment Procurement | 150d | 2028-06-16 | 2029-01-11 | 308 | 2026-05-27 | 2027-05-11 | 250d | 305d | 0d |  | HC-SUB-310 |
| 312 | 9.9.3 | Structures | 250d | 2029-01-12 | 2029-12-27 | 311 | 2026-05-27 | 2027-07-20 | 300d | 305d |  |  | HC-SUB-320 |
| 313 | 9.9.4 | **Commissioning** | 120d | 2031-02-28 | 2031-08-14 | 307 |  |  |  | 0d |  |  |  |
| 314 | 9.9.4 | Commission | 120d | 2031-02-28 | 2031-08-14 | 307, 216 | 2028-05-31 | 2028-07-11 | 30d | 0d |  |  | HC-SUB-400 |
| 315 | 1 | **CONSTRUCTION PACKAGE #5 - DUNNIGAN PIPELINE (ALT 1)** | 1579d | 2023-01-09 | 2029-01-25 |  |  |  |  | 755d |  |  |  |
| 316 | 1.1.1 | **Engineering** | 999d | 2023-01-09 | 2026-11-05 |  |  |  |  | 1124d |  |  |  |
| 317 | 1.1.1 | Preliminary (30%) | 235d | 2023-01-09 | 2023-12-01 |  | 2022-06-01 | 2023-03-07 | 200d | 1999d | 0d | start no earlier than 2023-01-09 | HC-DP1-100 |
| 318 | 14.1.2 | Class 3 Cost Estimate | 100d | 2023-12-04 | 2024-04-19 | 317 |  |  |  | 1999d |  |  |  |
| 319 | 5.5.1 | Final 60% Design | 130d | 2025-09-12 | 2026-03-12 | 11, 38FS-140d | 2023-06-14 | 2024-10-15 | 350d | 425d | 0d |  | HC-FRV-110 |
| 320 | 14.1.4 | Final 90% Design | 100d | 2026-03-13 | 2026-07-30 | 319 |  |  |  | 425d | 0d |  |  |
| 321 | 4.4.1 | Final 100% Design | 70d | 2026-07-31 | 2026-11-05 | 320 | 2023-06-14 | 2024-10-15 | 350d | 425d | 0d |  | HC-TPL-110 |
| 322 | 1.1.2 | **Bid and Award** | 90d | 2026-11-06 | 2027-03-11 |  |  |  |  | 860d |  |  |  |
| 323 | 1.1.2 | Bid and Award | 90d | 2026-11-06 | 2027-03-11 | 321 | 2024-02-21 | 2024-06-25 | 90d | 860d | 0d |  | HC-DP1-200 |

| ID | WBS | Task | Duration | Start | Finish | Predecessors | Baseline start | Baseline finish | Baseline duration | Total slack | Free slack | Constraint | Text1 |
| --- | --- | --- | --- | --- | --- | --- | --- | --- | --- | --- | --- | --- | --- |
| 324 | 1.1.3 | **Construction** | 465d | 2027-03-12 | 2028-12-21 |  |  |  |  | 780d |  |  |  |
| 325 | 1.1.3 | Submittals | 60d | 2027-03-12 | 2027-06-03 | 323 | 2024-06-26 | 2024-09-17 | 60d | 860d | 105d |  | HC-DP1-300 |
| 326 | 14.3.2 | **Field Construction** | 300d | 2027-10-29 | 2028-12-21 | 81, 83, 86FS-140d, 91 |  |  |  | 755d |  |  |  |
| 327 | 1.1.3 | TCC Intake Structure | 160d | 2027-10-29 | 2028-06-08 | 325 | 2024-09-18 | 2025-08-19 | 240d | 780d | 0d |  | HC-DP1-310 |
| 328 | 14.3.2.2 | CBD Discharge Structure | 140d | 2028-06-09 | 2028-12-21 | 327 |  |  |  | 780d |  |  |  |
| 329 | 1.1.3 | Pipeline | 250d | 2027-10-29 | 2028-10-12 | 325 | 2024-09-18 | 2025-09-02 | 250d | 755d | 0d |  | HC-DP1-320 |
| 330 | 1.1.3 | Testing | 45d | 2028-10-13 | 2028-12-14 | 327, 329 | 2025-09-03 | 2025-11-04 | 45d | 755d | 0d |  | HC-DP1-330 |
| 331 | 1.1.4 | **Commissioning** | 30d | 2028-12-15 | 2029-01-25 |  |  |  |  | 755d |  |  |  |
| 332 | 1.1.4 | Commission | 30d | 2028-12-15 | 2029-01-25 | 330 | 2025-11-05 | 2025-12-16 | 30d | 755d |  |  | HC-DP1-400 |
| 333 | 10 | **CONSTRUCTION PACKAGE #6 - RED BLUFF PUMPING PLANT (BY TCCA)** | 1130d | 2025-01-06 | 2029-05-04 |  |  |  |  | 684d |  |  |  |
| 334 | 10.10.1 | **Engineering** | 290d | 2025-01-06 | 2026-02-13 |  |  |  |  | 684d |  |  |  |
| 335 | 10.10.1 | Preliminary (30%) | 90d | 2025-01-06 | 2025-05-09 |  | 2023-01-02 | 2023-05-05 | 90d | 684d | 0d | start no earlier than 2025-01-06 | HC-RBP-100 |
| 336 | 10.10.1 | Final (60%, 90%, 100%) | 200d | 2025-05-12 | 2026-02-13 | 335 | 2023-05-08 | 2023-10-20 | 120d | 684d | 0d |  | HC-RBP-110 |
| 337 | 10.10.2 | **Bid and Award** | 90d | 2026-02-16 | 2026-06-19 |  |  |  |  | 684d |  |  |  |
| 338 | 10.10.2 | Bid and Award | 90d | 2026-02-16 | 2026-06-19 | 336 | 2024-09-30 | 2025-01-31 | 90d | 684d | 0d | start no earlier than 2024-09-30 | HC-RBP-200 |
| 339 | 10.10.3 | **Construction** | 720d | 2026-06-22 | 2029-03-23 |  |  |  |  | 684d |  |  |  |
| 340 | 10.10.3 | Submittals | 120d | 2026-06-22 | 2026-12-04 | 338 | 2025-02-03 | 2025-07-18 | 120d | 684d | 0d |  | HC-RBP-300 |
| 341 | 10.10.3 | Pump Procurement | 18mo | 2026-12-07 | 2028-04-21 | 340 | 2025-07-21 | 2026-04-24 | 200d | 684d | 0d |  | HC-RBP-310 |
| 342 | 10.10.3 | Mechanical/Electrical | 180d | 2028-04-24 | 2028-12-29 | 341 | 2026-04-27 | 2027-01-01 | 180d | 684d | 0d |  | HC-RBP-320 |
| 343 | 10.10.3 | Testing | 60d | 2029-01-01 | 2029-03-23 | 342 | 2027-01-04 | 2027-03-26 | 60d | 684d | 0d |  | HC-RBP-330 |
| 344 | 10.10.4 | **Commissioning** | 30d | 2029-03-26 | 2029-05-04 |  |  |  |  | 684d |  |  |  |
| 345 | 10.10.4 | Commission | 30d | 2029-03-26 | 2029-05-04 | 343 | 2027-03-29 | 2027-05-07 | 30d | 684d |  |  | HC-RBP-400 |
| 346 | 11 | **CONSTRUCTION PACKAGE #7 - GCID IMPROVMENTS (BY GCID)** | 1284d | 2025-01-06 | 2029-12-06 |  |  |  |  | 530d |  |  |  |
| 347 | 11.11.1 | **Engineering** | 440d | 2025-01-06 | 2026-09-11 |  |  |  |  | 594d |  |  |  |
| 348 | 11.11.1 | Preliminary (30%) | 120d | 2025-01-06 | 2025-06-20 |  | 2022-06-01 | 2023-06-13 | 270d | 594d | 0d | start no earlier than 2025-01-06 | HC-GCI-100 |
| 349 | 11.11.1 | Final (60%, 90%, 100%) | 320d | 2025-06-23 | 2026-09-11 | 348 | 2023-06-14 | 2024-10-15 | 350d | 594d | 0d |  | HC-GCI-110 |

| ID | WBS | Task | Duration | Start | Finish | Predecessors | Baseline start | Baseline finish | Baseline duration | Total slack | Free slack | Text1 |
| --- | --- | --- | --- | --- | --- | --- | --- | --- | --- | --- | --- | --- |
| 350 | 11.11.2 | **Bid and Award** | 90d | 2026-09-14 | 2027-01-15 |  |  |  |  | 594d |  |  |
| 351 | 11.11.2 | Bid and Award | 90d | 2026-09-14 | 2027-01-15 | 349 | 2024-10-16 | 2025-02-18 | 90d | 594d | 0d | HC-GCI-200 |
| 352 | 11.11.3 | **Construction** | 724d | 2027-01-18 | 2029-10-25 |  |  |  |  | 560d |  |  |
| 353 | 11.11.3 | Submittals | 120d | 2027-01-18 | 2027-07-02 | 351 | 2025-02-19 | 2025-08-05 | 120d | 594d | 64d | HC-GCI-300 |
| 354 | 16.3.2 | **Field Construction** | 480d | 2027-10-01 | 2029-08-02 | 81, 83, 86FS-160d, 91 |  |  |  | 530d |  |  |
| 355 | 11.11.3 | Structures | 24mo | 2027-10-01 | 2029-08-02 | 353 | 2025-08-06 | 2027-07-06 | 500d | 620d |  | HC-GCI-310 |
| 356 | 11.11.3 | Earthwork | 24mo | 2027-10-01 | 2029-08-02 | 353 | 2025-08-06 | 2027-07-06 | 500d | 530d | 0d | HC-GCI-320 |
| 357 | 11.11.3 | Testing | 60d | 2029-08-03 | 2029-10-25 | 356 | 2027-07-07 | 2027-09-28 | 60d | 530d | 0d | HC-GCI-330 |
| 358 | 11.11.4 | **Commissioning** | 30d | 2029-10-26 | 2029-12-06 |  |  |  |  | 530d |  |  |
| 359 | 11.11.4 | Commission | 30d | 2029-10-26 | 2029-12-06 | 357 | 2027-09-29 | 2027-11-09 | 30d | 530d |  | HC-GCI-400 |
