# Sites Reservoir Dams Construction - rev 6 11-09-20

Schedule from MS Project, 2023-06-01 to 2036-07-21.

## Calendars

- Standard: Mon-Fri 08:00-12:00, 13:00-17:00; Sat-Sun off.

## Resources

| Resource |
| --- |
| HDR |
| Authority |
| ICF |
| Attorneys |
| Auth/Atty/HDR |
| Auth/HDR |
| Public |
| Reclamation |
| USFWS |
| SHPO |

## Schedule

| ID | WBS | Task | Type | Duration | Start | Finish | Predecessors | Total slack | Free slack | Constraint | Dave Hardy notes |
| --- | --- | --- | --- | --- | --- | --- | --- | --- | --- | --- | --- |
| 1 | 1 | **Sites Reservoir - CP-1** |  | 3428d | 2023-06-01 | 2036-07-21 |  | -94d | 0d |  |  |
| 2 | 1.1 | **Final EIR / EIS** |  | 130d | 2023-06-01 | 2023-11-30 |  | 0d |  |  |  |
| 3 | 1.1.1 | Final EIR (Environmental Impact Report) CEQA Adoption | milestone, manual | 0d | 2023-06-01 | 2023-06-01 |  |  |  | start no earlier than 2023-06-01 | Final EIR expected 6/1/23. EIR Used for Schedule |
| 4 | 1.1.2 | Final EIS (Environmental Impact Statement) NEPA ROD | milestone, manual | 0d | 2023-11-30 | 2023-11-30 |  |  |  | start no earlier than 2023-11-30 | Final EIS expected 11/30/23. EIS Not Used for Schedule |
| 5 | 1.2 | CWC Award of Funds | milestone, manual | 0d | 2023-12-01 | 2023-12-01 |  |  |  |  |  |
| 6 | 1.3 | Sites Board Approval/NTP for Phase 3 | manual | 23d | 2023-12-01 | 2024-01-02 | 5 |  |  | start no earlier than 2024-01-03 |  |
| 7 | 1.4 | Determine Engineering Procurement & Delivery Method | milestone, manual | 0d | 2024-01-03 | 2024-01-03 | 6 |  |  |  |  |
| 8 | 1.5 | CMAR Solicitation and Procurement |  | 8mo | 2024-01-03 | 2024-08-13 | 7 | 1280d | 100d |  |  |
| 9 | 1.6 | Investor Commitment | milestone | 0d | 2024-10-24 | 2024-10-24 |  | 2878d |  | start no earlier than 2024-10-24 | Added Activity - Consider Predecessors/Successors |
| 10 | 1.7 | **Real Estate** |  | 1410d | 2024-01-03 | 2029-05-29 |  | 0d |  |  |  |
| 11 | 1.7.1 | **Land Access and Acquisition** |  | 1410d | 2024-01-03 | 2029-05-29 |  | 0d |  |  |  |
| 12 | 1.7.1.1 | Authority Approval to Proceed with P2 Access (NTP) | milestone, manual | 0d | 2024-01-03 | 2024-01-03 | 6 |  |  | start no earlier than 2023-05-01 |  |
| 13 | 1.7.1.2 | Critical Land Acquisition - P2a Geotech (Dam Foundation & Grouting) | milestone | 0d | 2027-07-06 | 2027-07-06 | 12, 94 | 2174d |  |  |  |
| 14 | 1.7.1.3 | Critical Land Acquisition - P2b Geotech Investigation (Dam Embankments) | milestone | 0d | 2027-06-22 | 2027-06-22 | 12, 117, 3 | 2184d |  |  |  |
| 15 | 1.7.1.4 | Critical Land Acquisition - P2a Geotech (Roads) | milestone | 0d | 2024-01-03 | 2024-01-03 | 12, 3 | 3089d |  |  |  |
| 16 | 1.7.1.5 | Critical Land Access - P2a Geotech (Dam Foundation & Grouting) |  | 200d | 2024-01-03 | 2024-10-08 | 12, 3 | 0d |  |  |  |
| 17 | 1.7.1.6 | Critical Land Acccess - P2b Geotech Investigation (Dam Embankments) |  | 200d | 2024-01-03 | 2024-10-08 | 12, 3 | 1579d | 250d |  |  |
| 18 | 1.7.1.7 | Critical Land Access - P2a Geotech (Roads) |  | 200d | 2024-01-03 | 2024-10-08 | 12, 3 | 860d | 0d | start no earlier than 2023-05-03 |  |
| 19 | 1.7.1.8 | Critical Path Land Acquisition |  | 700d | 2026-09-23 | 2029-05-29 | 92 | 0d |  |  | Added Activity |
| 20 | 1.7.1.9 | Land Acquisition / Complete Access | milestone | 0d | 2029-05-29 | 2029-05-29 | 19 | 0d |  |  | Moved activity from Permitting |
| 21 | 1.8 | **Environmental** |  | 21d | 2031-09-15 | 2031-10-14 |  | 0d |  |  |  |
| 22 | 1.8.1 | Environmental Surveys | milestone | 0mo | 2031-09-15 | 2031-09-15 | 31 | 21d |  |  |  |
| 23 | 1.8.2 | Environmental Permitting and Certification | milestone | 0mo | 2031-10-14 | 2031-10-14 | 22, 73, 78 | 0d |  |  |  |
| 24 | 1.9 | **Water** |  | 191d | 2024-01-02 | 2024-09-26 |  | 1670d |  |  |  |
| 25 | 1.9.1 | Water Right Permit | milestone | 0d | 2024-09-26 | 2024-09-26 | 6 | 2808d |  | start no earlier than 2024-09-26 |  |

Notes:
- 13: Text6: need to link to 90% plus 32 months line item. Test fill (blasting) is part of acquisition
- 14: Text6: need to link to 90% plus 32 months line item
- 15: Text6: need to link to 90% plus 32 months line item
- 16: Text6: access to the east side of GGD is EIR plus 9months
- 17: Text6: access to the east side of GGD is EIR plus 9months
- 18: Text6: access to the east side of GGD is EIR plus 9months
- 20: Spranza Notes: Based on completion of 90% Design + 32 months for compellment action

| ID | WBS | Task | Type | Duration | Start | Finish | Predecessors | Total slack | Free slack | Constraint |
| --- | --- | --- | --- | --- | --- | --- | --- | --- | --- | --- |
| 26 | 1.9.2 | **Construction Water** |  | 30d | 2024-01-02 | 2024-02-13 |  | 1670d |  |  |
| 27 | 1.9.2.1 | Acquisition of Construction Water | milestone | 0d | 2024-01-02 | 2024-01-02 | 6 | 1485d | 0d | start no earlier than 2023-12-15 |
| 28 | 1.9.2.2 | Initial Development of Construction Water |  | 30d | 2024-01-03 | 2024-02-13 | 27 | 1485d | 305d |  |
| 29 | 1.10 | **Sites Reservoir Permitting, Mitigation and Cultural Work** |  | 1974d | 2026-03-25 | 2033-10-17 |  | 0d |  |  |
| 30 | 1.10.1 | **Permitting** |  | 1429d | 2026-03-25 | 2031-09-15 |  | 21d |  |  |
| 31 | 1.10.1.1 | **Baseline Surveys and Revised ESA Consultation** |  | 1429d | 2026-03-25 | 2031-09-15 |  | 21d | 0d |  |
| 32 | 1.10.1.1.1 | Access Granted for Biological Surveys | milestone | 0d | 2026-03-25 | 2026-03-25 | 92SS | 252d | 0d |  |
| 33 | 1.10.1.1.2 | Plant Survey 1 |  | 15d | 2026-04-03 | 2026-04-23 | 32FS+7d | 1073d | 0d | start no earlier than 2026-03-16 |
| 34 | 1.10.1.1.3 | Plant Survey 2 |  | 15d | 2026-05-22 | 2026-06-11 | 33FS+20d | 1073d | 0d |  |
| 35 | 1.10.1.1.4 | Plant Survey 3 and Report |  | 45d | 2026-07-10 | 2026-09-10 | 34FS+20d | 1073d | 1052d |  |
| 36 | 1.10.1.1.5 | Land Cover Verification/Aquatic Delineation #1 |  | 15d | 2026-03-25 | 2026-04-14 | 32SS | 903d | 0d | start no earlier than 2025-12-02 |
| 37 | 1.10.1.1.6 | Land Cover Verification/Aquatic Delineation #2 |  | 15d | 2026-05-06 | 2026-05-26 | 36FS+15d | 903d | 0d |  |
| 38 | 1.10.1.1.7 | Land Cover Verification/Aquatic Delineation and Report |  | 45d | 2026-06-17 | 2026-08-18 | 37FS+15d | 903d | 0d |  |
| 39 | 1.10.1.1.8 | Revise Impact Acres and Work with Agencies |  | 60d | 2026-08-19 | 2026-11-10 | 38 | 903d | 862d |  |
| 40 | 1.10.1.1.9 | BUOW #1 (Burrowing Owls Study) | manual | 5d | 2030-04-01 | 2030-04-05 | 39, 20 |  |  | start no earlier than 2030-04-01 |
| 41 | 1.10.1.1.10 | BUOW #2 |  | 5d | 2030-04-29 | 2030-05-03 | 40FS+15d | 287d | 0d |  |
| 42 | 1.10.1.1.11 | BUOW #3 |  | 5d | 2030-06-03 | 2030-06-07 | 41FS+20d | 287d | 0d |  |
| 43 | 1.10.1.1.12 | BUOW #4 and Report |  | 30d | 2030-07-08 | 2030-08-16 | 42FS+20d | 287d | 0d |  |
| 44 | 1.10.1.1.13 | BUOW Relocation |  | 15d | 2030-08-19 | 2030-09-06 | 43 | 287d |  | start no earlier than 2027-08-27 |
| 45 | 1.10.1.1.14 | SWHA #1 and TCBB #1 | manual | 5d | 2030-03-01 | 2030-03-07 | 39, 20 |  |  | start no earlier than 2030-03-01 |
| 46 | 1.10.1.1.15 | SWHA #2 and TCBB #2 |  | 5d | 2030-03-29 | 2030-04-04 | 45FS+15d | 41d | 0d |  |
| 47 | 1.10.1.1.16 | SWHA #3 and TCBB #3 |  | 5d | 2030-04-26 | 2030-05-02 | 46FS+15d | 41d | 0d |  |
| 48 | 1.10.1.1.17 | SWHA #4 |  | 5d | 2030-05-31 | 2030-06-06 | 47FS+20d | 41d | 0d |  |
| 49 | 1.10.1.1.18 | SWHA #5 |  | 5d | 2030-06-28 | 2030-07-04 | 48FS+15d | 41d | 0d |  |
| 50 | 1.10.1.1.19 | SWHA #6 and Report |  | 30d | 2030-07-16 | 2030-08-26 | 49FS+7d | 41d | 20d |  |
| 51 | 1.10.1.1.20 | TCBB Report |  | 30d | 2030-05-03 | 2030-06-13 | 47 | 93d | 72d |  |
| 52 | 1.10.1.1.21 | Vernal Pool Wet Season Survey 1 |  | 10d | 2029-12-03 | 2029-12-14 | 36SS | 142d | 0d | start no earlier than 2029-12-03 |
| 53 | 1.10.1.1.22 | Vernal Pool Wet Season Survey 2 |  | 10d | 2030-01-07 | 2030-01-18 | 52FS+15d | 142d | 0d |  |
| 54 | 1.10.1.1.23 | Vernal Pool Wet Season Survey 3 |  | 10d | 2030-02-11 | 2030-02-22 | 53FS+15d | 142d | 0d |  |
| 55 | 1.10.1.1.24 | Vernal Pool Wet Season Survey 4 (more may be needed) and Report |  | 60d | 2030-03-18 | 2030-06-07 | 54FS+15d | 142d | 88d |  |
| 56 | 1.10.1.1.25 | VELB Survey and Report |  | 30d | 2030-04-30 | 2030-06-10 | 19 | 21d | 0d | start no earlier than 2030-04-30 |
| 57 | 1.10.1.1.26 | VELB Transplant |  | 20d | 2031-01-07 | 2031-02-03 | 56FS+150d | 181d |  |  |
| 58 | 1.10.1.1.27 | Bank Swallow Survey and Report |  | 30d | 2030-05-03 | 2030-06-13 | 47 | 93d | 0d |  |
| 59 | 1.10.1.1.28 | CRLF Surveys and Report |  | 200d | 2030-01-03 | 2030-10-09 | 32 | 54d | 0d | start no earlier than 2030-01-03 |
| 60 | 1.10.1.1.29 | Bumble Bee Survey 1 |  | 5d | 2030-04-30 | 2030-05-06 | 56SS | 21d | 0d |  |
| 61 | 1.10.1.1.30 | Bumble Bee Survey 2 |  | 5d | 2030-05-28 | 2030-06-03 | 60FS+15d | 21d | 0d |  |
| 62 | 1.10.1.1.31 | Bumble Bee Survey 3 |  | 5d | 2030-06-25 | 2030-07-01 | 61FS+15d | 21d | 0d |  |
| 63 | 1.10.1.1.32 | Bumble Bee Survey 4 and Report |  | 45d | 2030-07-23 | 2030-09-23 | 62FS+15d | 21d | 0d |  |
| 64 | 1.10.1.1.33 | Badger Survey and Report |  | 30d | 2030-06-14 | 2030-07-25 | 58 | 298d | 0d |  |
| 65 | 1.10.1.1.34 | Bat Survey (Roosts) |  | 10d | 2030-07-26 | 2030-08-08 | 64 | 298d | 0d |  |
| 66 | 1.10.1.1.35 | Bat Roosts Removal |  | 10d | 2030-08-09 | 2030-08-22 | 65 | 298d |  |  |
| 67 | 1.10.1.1.36 | USFWS - Amend ESA Consultation: Prepare Report and Submit |  | 90d | 2030-10-10 | 2031-02-12 | 35, 50, 55, 56, 59 | 54d | 0d |  |
| 68 | 1.10.1.1.37 | USFWS Review and Amend ESA Permit and Take Statement |  | 120d | 2031-02-13 | 2031-07-30 | 67 | 54d |  |  |
| 69 | 1.10.1.1.38 | CDFW - Amend ESA ITP: Prepare Report and Submit |  | 90d | 2030-09-24 | 2031-01-27 | 35, 50, 51, 58, 63 | 21d | 0d |  |
| 70 | 1.10.1.1.39 | CDFW Review Report and Ament ITP Take Statement |  | 120d | 2031-01-28 | 2031-07-14 | 69 | 21d | 0d |  |
| 71 | 1.10.1.1.40 | Precon Avoidance (GGS, Avian, mammal, other CEQA spp) |  | 30d | 2031-08-05 | 2031-09-15 | 70FS+15d | 21d |  |  |

Notes:
- 30: this is an aggressive schedule and best case scenario. / Spranza Notes: All permitting schedule is seasonally timed
- 31: Note: Protocol surveys have required start/stop dates and conditions (rain) requirements. This schedule assumes only one year of surveys needed. 50% probability of additional year for some will be required / Spranza Notes: Assumes only 1 year of surveys needed. 50% probability some will require 2
- 32: assumes GG Dame 60% design / Spranza Notes: Assumes access granted at 60% Design
- 33: Protocol Survey: must start in Mar and may take more than one year of conditions (rain) does not meet protocol requirements. Agencies may also require a second year (50% prop) / Spranza Notes: Protocol Survey: Must start in Mar - Spranza
- 34: Protocol Survey: must start in Mar and may take more than one year of conditions (rain) does not meet protocol requirements. Agencies may also require a second year (50% prop / Spranza Notes: Protocol Survey: Spranza
- 35: Protocol Survey: must start in Mar and may take more than one year of conditions (rain) does not meet protocol requirements. Agencies may also require a second year (50% prop / Spranza Notes: Protocol Survey: Spranza
- 36: Spranza Notes: Series starts in rainy season - December
- 39: Spranza Notes: Timing dependent on impact change and agency review time
- 40: Spranza Notes: Protocol Survey: Start April - Spranza
- 41: Spranza Notes: Protocol Survey: Spranza
- 42: Spranza Notes: Protocol Survey: Spranza
- 43: Spranza Notes: Protocol Survey: Spranza
- 44: Spranza Notes: Duration could vary depending on numbers
- 45: Protocol Survey: Must Start in March / Spranza Notes: Protocol Survey: Must Start in March
- 46: Spranza Notes: Protocol Survey: Spranza
- 47: Spranza Notes: Protocol Survey: Spranza
- 48: Spranza Notes: Protocol Survey: Spranza
- 49: Spranza Notes: Protocol Survey: Spranza
- 50: Spranza Notes: Protocol Survey: Spranza
- 52: Protocol Survey: must start in Dec and will go through entire wet season. This survey can take more than one year if rainfall is not sufficient to meet protocol requirements. / Spranza Notes: Protocol Survey: Must start in Dec - Spranza
- 53: Protocol Survey: must start in Dec and will go through entire wet season. This survey can take more than one year if rainfall is not sufficient to meet protocol requirements. / Spranza Notes: Protocol Survey: Spranza
- 54: Spranza Notes: Protocol Survey: Spranza
- 55: Protocol Survey: must start in Dec and will go through entire wet season. This survey can take more than one year if rainfall is not sufficient to meet protocol requirements. / Spranza Notes: Protocol Survey: Spranza additional may be needed
- 56: Spranza Notes: Start in April recommended
- 57: Must be done from Dec-Mar - Spranza / Spranza Notes: Must be done from Dec-Mar - Spranza
- 58: Spranza Notes: Must start May or June
- 59: Protocol Survey: must start in January / Spranza Notes: Protocol Survey: must start in January - Spranza
- 60: Protocol Survey: must start in April / Spranza Notes: Protocol Survey: Must begin in April - Spranza
- 61: Spranza Notes: Protocol Survey: Spranza
- 62: Spranza Notes: Protocol Survey: Spranza
- 63: Spranza Notes: Protocol Survey: Spranza
- 68: Spranza Notes: Timing dependent on impact change and agency review time
- 69: Spranza Notes: Timing dependent on impact change and agency review time
- 70: Spranza Notes: Timing dependent on impact change and agency review time
- 71: Pre-con avoidance surveys for all sensative species are based on each construction area timing of impact, type of effect and could result in delay to start if species found. / Spranza Notes: Surveys based on each construction area timing

| ID | WBS | Task | Type | Duration | Start | Finish | Predecessors | Total slack | Free slack | Constraint | Dave Hardy notes |
| --- | --- | --- | --- | --- | --- | --- | --- | --- | --- | --- | --- |
| 72 | 1.10.2 | **Compensatory Mitigation** |  | 305d | 2027-03-12 | 2028-05-11 |  |  |  |  |  |
| 73 | 1.10.2.1 | Secure LOC/Implement Mitigation Prior to Take |  | 305d | 2027-03-12 | 2028-05-11 | 32 | 0d |  |  |  |
| 74 | 1.10.3 | **Cultural Work** |  | 1974d | 2026-03-25 | 2033-10-17 |  | 0d |  |  |  |
| 75 | 1.10.3.1 | Prepare and Consult on Construction Phase Work Plan (per Section 106 PA) |  | 120d | 2026-03-25 | 2026-09-08 | 32 | 953d | 710d |  |  |
| 76 | 1.10.3.2 | Cultural Survey - with Fee Title |  | 180d | 2029-05-30 | 2030-02-05 | 75, 20 | 0d |  |  |  |
| 77 | 1.10.3.3 | Testing and Evaluation of Resources |  | 180d | 2030-02-06 | 2030-10-15 | 76 | 0d |  |  |  |
| 78 | 1.10.3.4 | Develop Treatment Plan and Implementation |  | 260d | 2030-10-16 | 2031-10-14 | 76, 73, 77 | 0d |  |  |  |
| 79 | 1.10.3.5 | Implement Avoidance/Minimization Activities During Construction |  | 260d | 2032-10-19 | 2033-10-17 | 78, 321 | 0d |  |  |  |
| 80 | 1.11 | **P1 / P2 Geotech Investigations** |  | 669d | 2023-08-31 | 2026-03-24 |  | -159d | 0d |  |  |
| 81 | 1.11.1 | P1 Geotech Investigation (30% Cutoff) | milestone | 0d | 2023-08-31 | 2023-08-31 | 3 | -159d | 0d | start no earlier than 2023-08-31 |  |
| 82 | 1.11.2 | EIR P2a Geotech Investigation (Dam Foundations & Grouting) |  | 76w | 2024-10-09 | 2026-03-24 | 16, 81 | 0d |  | start no earlier than 2023-05-03 | Work could begin earlier with earlier access procurement |
| 83 | 1.11.3 | EIR P2a Geotech Investigation (Roads) |  | 76w | 2024-10-09 | 2026-03-24 | 81, 18 | 1045d | 0d | start no earlier than 2023-05-03 | Work could begin earlier with earlier access procurement |
| 84 | 1.11.4 | EIR P2b Geotech Investigation (Dam Embankments) |  | 26w | 2025-09-24 | 2026-03-24 | 17, 82SS+50w | 1514d | 0d | start no earlier than 2023-05-03 |  |
| 85 | 1.12 | **Reservoir Facilities** |  | 3363d | 2023-08-31 | 2036-07-21 |  | -159d | 0d |  |  |
| 86 | 1.12.1 | **Engineering - Dams** |  | 1374d | 2023-08-31 | 2028-12-05 |  | -159d | 0d |  |  |
| 87 | 1.12.1.1 | **Golden Gate Dam Design** |  | 1239d | 2023-08-31 | 2028-05-30 |  | -139d | 0d |  |  |
| 88 | 1.12.1.1.1 | **Golden Gate Foundation Design** |  | 1239d | 2023-08-31 | 2028-05-30 |  | -139d | 0d |  |  |
| 89 | 1.12.1.1.1.1 | Golden Gate Foundation 30% Design |  | 151d | 2023-08-31 | 2024-03-28 | 81 | -139d | 0d | finish no later than 2024-03-29 |  |
| 90 | 1.12.1.1.1.2 | Golden Gate Fnd 30% Design Package Submittal | milestone | 0d | 2024-03-28 | 2024-03-28 | 89 | 587d | 0d |  |  |
| 91 | 1.12.1.1.1.3 | DSOD Review of GG Fdn 30% Design |  | 26w | 2024-03-29 | 2024-09-26 | 90 | 508d |  |  |  |
| 92 | 1.12.1.1.1.4 | Golden Gate Foundation 60% Design |  | 26w | 2026-03-25 | 2026-09-22 | 82, 91SS+10d | 0d |  |  |  |
| 93 | 1.12.1.1.1.5 | DSOD Review of GG Fdn 60% Design |  | 26w | 2026-09-23 | 2027-03-23 | 92 | 1044d | 0d |  |  |
| 94 | 1.12.1.1.1.6 | Golden Gate Foundation 90% Design |  | 39w | 2026-10-07 | 2027-07-06 | 93SS+10d | 1044d | 0d |  |  |
| 95 | 1.12.1.1.1.7 | DSOD Review of GG Fdn 90% Design |  | 26w | 2027-07-07 | 2028-01-04 | 94 | 1044d | 0d |  |  |
| 96 | 1.12.1.1.1.8 | GG Foundation 100% Design |  | 33w | 2027-07-21 | 2028-03-07 | 95SS+10d | 1044d | 0d |  |  |
| 97 | 1.12.1.1.1.9 | DSOD Review of GG 100% Foundation Design Package |  | 12w | 2028-03-08 | 2028-05-30 | 96 | 1044d | 0d |  |  |
| 98 | 1.12.1.1.1.10 | GG Foundation DSOD Approval Received | milestone | 0d | 2028-05-30 | 2028-05-30 | 97 | 859d | 19d |  |  |

Notes:
- 79: Spranza Notes: Activities to be done during construction to minimize, avoid and mitigate. Would start with construction
- 81: End Date different than Jeff / Jeff W. Notes: P1 only gives us 30% for *all* features including roads, see below
- 89: Already started? Used 200 Days instead of 457 days / Jeff W. Notes: This could be considered a fixed NLT date
- 92: Used 39 weeks instead of 78 weeks / Jeff W. Notes: Reduce to 26 weeks
- 94: Used 25 weeks instead of 39 weeks
- 96: Maintained 13 weeks

| ID | WBS | Task | Type | Duration | Start | Finish | Predecessors | Total slack | Free slack | Constraint | Jeff W. Notes |
| --- | --- | --- | --- | --- | --- | --- | --- | --- | --- | --- | --- |
| 99 | 1.12.1.1.2 | **Golden Gate Grouting Design** |  | 1129d | 2023-08-31 | 2027-12-28 |  | 61d |  |  |  |
| 100 | 1.12.1.1.2.1 | Golden Gate Grouting 30% Design |  | 91d | 2023-08-31 | 2024-01-04 | 89SS, 81 | 61d | 0d | finish no later than 2024-03-29 | Use same logic as 14, finish NLT FRI 3/29/24 |
| 101 | 1.12.1.1.2.2 | Golden Gate Grouting Design Package Submittal | milestone | 0d | 2024-01-04 | 2024-01-04 | 81, 100 | 1857d | 0d |  |  |
| 102 | 1.12.1.1.2.3 | DSOD Review of GG Grouting 30% Design |  | 26w | 2024-01-05 | 2024-07-04 | 101 | 2042d | 568d |  |  |
| 103 | 1.12.1.1.2.4 | Golden Gate Grouting 60% Design |  | 26w | 2026-03-25 | 2026-09-22 | 102SS+10d, 82 | 1474d | 0d |  | Reduce to 26 weeks |
| 104 | 1.12.1.1.2.5 | DSOD Review of GG Grouting 60% Design |  | 26w | 2026-09-23 | 2027-03-23 | 103 | 1474d | 0d |  |  |
| 105 | 1.12.1.1.2.6 | Golden Gate Grouting 90% Design |  | 24w | 2026-10-07 | 2027-03-23 | 104SS+10d | 1474d | 0d |  |  |
| 106 | 1.12.1.1.2.7 | DSOD Review of GG Grouting 90% Design |  | 26w | 2027-03-24 | 2027-09-21 | 105, 104 | 1474d | 0d |  |  |
| 107 | 1.12.1.1.2.8 | GG Grouting 100% Design |  | 26w | 2027-04-07 | 2027-10-05 | 106SS+10d | 1474d | 0d |  |  |
| 108 | 1.12.1.1.2.9 | DSOD Review of GG 100% Grouting Design Package |  | 12w | 2027-10-06 | 2027-12-28 | 107 | 1474d | 0d |  |  |
| 109 | 1.12.1.1.2.10 | GG Grouting DSOD Approval Received | milestone | 0d | 2027-12-28 | 2027-12-28 | 108 | 1289d |  |  |  |
| 110 | 1.12.1.1.3 | **Golden Gate Embankment Design** |  | 1128d | 2023-11-24 | 2028-03-21 |  | 0d |  |  |  |
| 111 | 1.12.1.1.3.1 | Golden Gate Embankment 30% Design |  | 91d | 2023-11-24 | 2024-03-29 | 81, 89SS+200d | -139d | 0d | finish no later than 2024-03-29 | Use same logic as 14, finish NLT FRI 3/29/24 |
| 112 | 1.12.1.1.3.2 | Golden Gate Embankment Design Package Submittal | milestone | 0d | 2024-03-29 | 2024-03-29 | 111, 81 | 1911d | 0d |  |  |
| 113 | 1.12.1.1.3.3 | DSOD Review of GG Embankment 30% Design |  | 26w | 2024-04-01 | 2024-09-27 | 112 | 2096d | 582d |  |  |
| 114 | 1.12.1.1.3.4 | Golden Gate Borrow and Quarry Geotech Data | milestone | 0d | 2026-03-24 | 2026-03-24 | 84 | 1329d | 0d |  |  |
| 115 | 1.12.1.1.3.5 | Golden Gate Embankment 60% Design |  | 39w | 2026-03-25 | 2026-12-22 | 114 | 1514d | 0d |  |  |
| 116 | 1.12.1.1.3.6 | DSOD Review of GG Embankment 60% Design |  | 26w | 2026-12-23 | 2027-06-22 | 115, 113 | 1514d | 0d |  |  |
| 117 | 1.12.1.1.3.7 | Golden Gate Embankment 90% Design |  | 24w | 2027-01-06 | 2027-06-22 | 116SS+10d | 1514d | 0d |  |  |
| 118 | 1.12.1.1.3.8 | DSOD Review of GG Embankment 90% Design |  | 26w | 2027-06-23 | 2027-12-21 | 117 | 1514d | 0d |  |  |
| 119 | 1.12.1.1.3.9 | GG Embankment 100% Design |  | 25w | 2027-07-07 | 2027-12-28 | 118SS+10d | 1514d | 0d |  |  |
| 120 | 1.12.1.1.3.10 | DSOD Review of GG 100% Embankment Design Package |  | 12w | 2027-12-29 | 2028-03-21 | 119 | 1514d | 0d |  |  |
| 121 | 1.12.1.1.3.11 | GG Embankment DSOD Approval Received | milestone | 0d | 2028-03-21 | 2028-03-21 | 120 | 1329d |  |  |  |
| 122 | 1.12.1.2 | **Sites Dam Design** |  | 1374d | 2023-08-31 | 2028-12-05 |  | -159d | 0d |  |  |
| 123 | 1.12.1.2.1 | **Sites Dam Foundation and Outlet Design** |  | 1319d | 2023-08-31 | 2028-09-19 |  | -159d | 0d |  |  |
| 124 | 1.12.1.2.1.1 | Sites Dam Foundation and Outlet 30% Design |  | 151d | 2023-08-31 | 2024-03-28 | 81 | -159d | 0d | finish no later than 2024-03-29 | Use same logic as 14, finish NLT FRI 3/29/24 |
| 125 | 1.12.1.2.1.2 | Sites Dam Foundation and Outlet Design Package Submittal | milestone | 0d | 2024-03-28 | 2024-03-28 | 124 | 1742d | 0d |  |  |
| 126 | 1.12.1.2.1.3 | DSOD Review of Sites Dam Foundation and Outlet 30% Design |  | 26w | 2024-03-29 | 2024-09-26 | 125 | 1927d | 508d |  |  |
| 127 | 1.12.1.2.1.4 | Sites Dam Foundation and Outlet Geotech Data | milestone | 0d | 2026-03-24 | 2026-03-24 | 82 | 1234d | 0d |  |  |
| 128 | 1.12.1.2.1.5 | Sites Dam Foundation and Outlet 60% Design |  | 39w | 2026-03-25 | 2026-12-22 | 127, 126SS+10d | 1419d | 0d |  |  |
| 129 | 1.12.1.2.1.6 | DSOD Review of Sites Dam Foundation and Outlet 60% Design |  | 26w | 2026-12-23 | 2027-06-22 | 128 | 1419d | 0d |  |  |
| 130 | 1.12.1.2.1.7 | Sites Dam Foundation and Outlet 90% Design |  | 49w | 2027-01-06 | 2027-12-14 | 129SS+10d | 1419d | 0d |  |  |
| 131 | 1.12.1.2.1.8 | DSOD Review of Sites Dam Foundation and Outlet 90% Design |  | 26w | 2027-12-15 | 2028-06-13 | 130 | 1419d | 0d |  |  |
| 132 | 1.12.1.2.1.9 | Sites Dam Foundation and Outlet 100% Design |  | 26w | 2027-12-29 | 2028-06-27 | 131SS+10d | 1419d | 0d |  |  |
| 133 | 1.12.1.2.1.10 | DSOD Review of Sites 100% Foundation and Outlet Design |  | 12w | 2028-06-28 | 2028-09-19 | 132 | 1419d | 0d |  |  |
| 134 | 1.12.1.2.1.11 | Sites Dam Foundation and Outlet DSOD Approval Received | milestone | 0d | 2028-09-19 | 2028-09-19 | 133 | 1234d | 0d |  |  |

Notes:
- 100: Used 100 Days
- 103: Used 39 weeks instead of 78 weeks
- 105: Used 25 weeks instead of 39 weeks
- 107: Maintained 13 weeks
- 111: Used 100 Days
- 115: Used 39 weeks instead of 78 weeks
- 117: Used 25 weeks instead of 39 weeks
- 119: Maintained 13 weeks
- 123: Parallel to GG Design
- 124: Already started? Used 200 Days instead of 457 days
- 128: Used 39 weeks instead of 78 weeks
- 130: Used 25 weeks instead of 39 weeks
- 132: Maintained 13 weeks

| ID | WBS | Task | Type | Duration | Start | Finish | Predecessors | Total slack | Free slack | Constraint | Jeff W. Notes |
| --- | --- | --- | --- | --- | --- | --- | --- | --- | --- | --- | --- |
| 135 | 1.12.1.2.2 | **Sites Dam Grouting Design** |  | 1333d | 2023-10-27 | 2028-12-05 |  | -100d | 0d |  |  |
| 136 | 1.12.1.2.2.1 | Sites Dam Grouting 30% Design |  | 111d | 2023-10-27 | 2024-03-29 | 81, 124SS+100d | -100d | 0d | finish no later than 2024-03-29 | Use same logic as 14, finish NLT FRI 3/29/24 |
| 137 | 1.12.1.2.2.2 | Sites Dam Grouting Design Package Submittal | milestone | 0d | 2024-03-29 | 2024-03-29 | 81, 136 | 1736d | 0d |  |  |
| 138 | 1.12.1.2.2.3 | DSOD Review of Sites Dam Grouting 30% Design |  | 26w | 2024-04-01 | 2024-09-27 | 137 | 1921d | 387d |  |  |
| 139 | 1.12.1.2.2.4 | Sites Dam Grouting Geotech Data | milestone | 0d | 2026-03-24 | 2026-03-24 | 82 | 1349d | 0d |  |  |
| 140 | 1.12.1.2.2.5 | Sites Dam Grouting 60% Design |  | 39w | 2026-03-25 | 2026-12-22 | 139, 138 | 1534d | 0d |  |  |
| 141 | 1.12.1.2.2.6 | DSOD Review of Sites Dam Grouting 60% Design |  | 26w | 2026-12-23 | 2027-06-22 | 140 | 1534d | 0d |  |  |
| 142 | 1.12.1.2.2.7 | Sites Dam Grouting 90% Design |  | 49w | 2027-01-06 | 2027-12-14 | 141SS+10d | 1534d | 0d |  |  |
| 143 | 1.12.1.2.2.8 | DSOD Review of Sites Dam Grouting 90% Design |  | 26w | 2027-12-15 | 2028-06-13 | 142 | 1534d | 0d |  |  |
| 144 | 1.12.1.2.2.9 | Sites Dam Grouting 100% Design |  | 37w | 2027-12-29 | 2028-09-12 | 143SS+10d | 1534d | 0d |  |  |
| 145 | 1.12.1.2.2.10 | DSOD Review of Sites 100% Grouting Design Package |  | 12w | 2028-09-13 | 2028-12-05 | 144 | 1534d | 0d |  |  |
| 146 | 1.12.1.2.2.11 | Sites Dam Grouting DSOD Approval Received | milestone | 0d | 2028-12-05 | 2028-12-05 | 145 | 1349d | 115d |  |  |
| 147 | 1.12.1.2.3 | **Sites Dam Embankment Design** |  | 1333d | 2023-10-27 | 2028-12-05 |  | 0d |  |  |  |
| 148 | 1.12.1.2.3.1 | Sites Dam Embankment 30% Design |  | 111d | 2023-10-27 | 2024-03-29 | 81, 136SS+100d | -100d | 0d | finish no later than 2024-03-29 | Use same logic as 14, finish NLT FRI 3/29/24 |
| 149 | 1.12.1.2.3.2 | Sites Dam Embankment Design Package Submittal | milestone | 0d | 2024-03-29 | 2024-03-29 | 81, 148 | 1806d | 0d |  |  |
| 150 | 1.12.1.2.3.3 | DSOD Review of Sites Dam Embankment 30% Design |  | 26w | 2024-04-01 | 2024-09-27 | 149 | 1991d | 387d |  |  |
| 151 | 1.12.1.2.3.4 | Sites Dam Borrow and Quarry Geotech Data | milestone | 0d | 2026-03-24 | 2026-03-24 | 84 | 1419d | 0d |  |  |
| 152 | 1.12.1.2.3.5 | Sites Dam Embankment 60% Design |  | 39w | 2026-03-25 | 2026-12-22 | 127, 151, 150 | 1604d | 0d |  |  |
| 153 | 1.12.1.2.3.6 | DSOD Review of Sites Dam Embankment 60% Design |  | 26w | 2026-12-23 | 2027-06-22 | 152 | 1604d | 0d |  |  |
| 154 | 1.12.1.2.3.7 | Sites Dam Embankment 90% Design |  | 49w | 2027-01-06 | 2027-12-14 | 153SS+10d | 1604d | 0d |  |  |
| 155 | 1.12.1.2.3.8 | DSOD Review of Sites Dam Embankment 90% Design |  | 26w | 2027-12-15 | 2028-06-13 | 154 | 1604d | 0d |  |  |
| 156 | 1.12.1.2.3.9 | Sites Dam Embankment 100% Design |  | 37w | 2027-12-29 | 2028-09-12 | 155SS+10d | 1604d | 0d |  |  |
| 157 | 1.12.1.2.3.10 | DSOD Review of Sites 100% Embankment Design Package |  | 12w | 2028-09-13 | 2028-12-05 | 156 | 1604d | 0d |  |  |
| 158 | 1.12.1.2.3.11 | Sites Dam Embankment DSOD Approval Received | milestone | 0d | 2028-12-05 | 2028-12-05 | 157 | 1419d | 185d |  |  |

Notes:
- 135: Parallel to GG Design
- 136: Used 200 Days instead of 457 days
- 140: Used 39 weeks instead of 78 weeks
- 142: Used 25 weeks instead of 39 weeks
- 144: Maintained 13 weeks
- 147: Parallel to GG Design
- 148: Used 200 Days instead of 457 days
- 152: Used 39 weeks instead of 78 weeks
- 154: Used 25 weeks instead of 39 weeks
- 156: Maintained 13 weeks

| ID | WBS | Task | Type | Duration | Start | Finish | Predecessors | Total slack | Free slack | Constraint | Jeff W. Notes | Construction Package | Dave Hardy notes |
| --- | --- | --- | --- | --- | --- | --- | --- | --- | --- | --- | --- | --- | --- |
| 159 | 1.12.1.3 | **Saddle Dam Designs** |  | 1159d | 2023-08-31 | 2028-02-08 |  | 1d |  |  |  |  |  |
| 160 | 1.12.1.3.1 | Saddle Dams 30% Design |  | 151d | 2023-08-31 | 2024-03-28 | 81 | 1d |  | finish no later than 2024-03-29 | Use same logic as 14, finish NLT FRI 3/29/24 |  |  |
| 161 | 1.12.1.3.2 | Saddle Dams 30% Design Package Submittal | milestone, manual | 0d | 2024-04-01 | 2024-04-01 | 160 |  |  | start no earlier than 2024-07-01 |  |  |  |
| 162 | 1.12.1.3.3 | Saddle Dams DSOD Review of 30% Design |  | 26w | 2024-04-01 | 2024-09-27 | 161 | 1781d | 387d |  |  |  |  |
| 163 | 1.12.1.3.4 | Saddle Dams Borrow and Quarry Geotech Data | milestone | 0d | 2026-03-24 | 2026-03-24 | 82, 84 | 1394d | 0d |  |  |  |  |
| 164 | 1.12.1.3.5 | Saddle Dams 60% Design |  | 36w | 2026-03-25 | 2026-12-01 | 163, 162 | 1579d | 0d |  |  |  |  |
| 165 | 1.12.1.3.6 | Saddle Dams DSOD Review of 60% Design |  | 26w | 2026-12-02 | 2027-06-01 | 164 | 1579d | 0d |  |  |  |  |
| 166 | 1.12.1.3.7 | Saddle Dams 90% Design |  | 26w | 2026-12-16 | 2027-06-15 | 165SS+10d | 1579d | 0d |  |  |  |  |
| 167 | 1.12.1.3.8 | Saddle Dams DSOD Review of 90% Design |  | 26w | 2027-06-16 | 2027-12-14 | 166 | 1579d | 0d |  |  |  |  |
| 168 | 1.12.1.3.9 | Saddle Dams 100% Design |  | 26w | 2027-06-30 | 2027-12-28 | 167SS+10d | 1579d | 0d |  |  |  |  |
| 169 | 1.12.1.3.10 | DSOD Review of 100% Package |  | 6w | 2027-12-29 | 2028-02-08 | 168 | 1579d | 0d |  |  |  |  |
| 170 | 1.12.1.3.11 | Saddle Dams DSOD Approval Received | milestone | 0d | 2028-02-08 | 2028-02-08 | 169 | 1394d | 0d |  |  |  |  |
| 171 | 1.12.2 | **CMAR Procurement** |  | 195d | 2025-01-01 | 2025-09-30 |  | 1365d |  |  |  |  |  |
| 172 | 1.12.2.1 | Award CMAR Contract | milestone | 0d | 2025-01-01 | 2025-01-01 | 8 | 1180d | 0d | start no earlier than 2025-01-01 |  |  |  |
| 173 | 1.12.2.2 | Notice to Proceed |  | 6w | 2025-01-01 | 2025-02-11 | 172 | 1180d | 0d |  |  |  |  |
| 174 | 1.12.2.3 | Early Submittals And Approvals - Dams |  | 90d | 2025-02-12 | 2025-06-17 | 173 | 1180d | 0d |  |  |  |  |
| 175 | 1.12.2.4 | CMAR Mobilization |  | 6mo | 2025-04-16 | 2025-09-30 | 173, 174SS+45d, 27, 28 | 1180d | 0d |  |  |  |  |
| 176 | 1.12.3 | **Roads, Bridges, Access, and Site Development** |  | 2023d | 2024-08-28 | 2032-05-31 |  | 990d |  |  |  |  |  |
| 177 | 1.12.3.1 | Early Site Access and Staging Development |  | 100d | 2025-04-16 | 2025-09-02 | 175SS | 2393d | 0d |  |  |  |  |
| 178 | 1.12.3.2 | **Northern Construction Access Roads (CR 68, CR 69, N. Rd)** |  | 784d | 2029-05-29 | 2032-05-31 |  | 0d |  |  |  |  |  |
| 179 | 1.12.3.2.1 | Geotechnical Data | milestone | 0d | 2029-05-29 | 2029-05-29 | 83, 19 | 215d | 0d |  |  |  |  |
| 180 | 1.12.3.2.2 | Final Design |  | 39w | 2029-05-30 | 2030-02-26 | 179 | 215d | 0d |  |  |  |  |
| 181 | 1.12.3.2.3 | Procurement and NTP |  | 90d | 2030-02-27 | 2030-07-02 | 175, 180 | 215d |  |  |  |  |  |
| 182 | 1.12.3.2.4 | Northern Construction Access Roads (CR 68, CR 69, N. Rd) |  | 284d | 2031-04-30 | 2032-05-31 | 181, 19FS-24w, 23FS-24w | 0d |  |  |  | C1-RB1 | Already predecessor to 321 |

Notes:
- 160: Already started? Used 200 Days instead of 457 days
- 164: Was 78 Weeks
- 166: Was 36 Weeks
- 172: Jeff's Dates
- 173: Jeff's Dates

| ID | WBS | Task | Type | Duration | Start | Finish | Predecessors | Total slack | Free slack | Jeff W. Notes | Construction Package | Dave Hardy notes |
| --- | --- | --- | --- | --- | --- | --- | --- | --- | --- | --- | --- | --- |
| 183 | 1.12.3.3 | **County Roads F, D, McDermott, Delevan** |  | 574d | 2024-08-28 | 2026-11-10 |  | 1449d |  |  |  |  |
| 184 | 1.12.3.3.1 | Geotechnical Data | milestone | 0d | 2024-08-28 | 2024-08-28 | 81FS+52w | 1288d | 0d | Assume P2a (Roads) |  |  |
| 185 | 1.12.3.3.2 | Final Design |  | 52w | 2024-08-29 | 2025-08-27 | 184 | 1452d | 24d |  |  |  |
| 186 | 1.12.3.3.3 | Procurement and NTP |  | 90d | 2025-10-01 | 2026-02-03 | 175, 185 | 1428d | 0d |  |  |  |
| 187 | 1.12.3.3.4 | County Roads F, D, McDermott, Delevan |  | 200d | 2026-02-04 | 2026-11-10 | 186 | 1264d | 315d |  | C1-RB2 | Added as predecessor to 321 |
| 188 | 1.12.3.4 | **Southern Construction Access Roads (Maxwell-Sites, Shoo-fly, A-1)** |  | 775d | 2029-05-29 | 2032-05-18 |  | 289d |  |  |  |  |
| 189 | 1.12.3.4.1 | Geotechnical Data | milestone | 0d | 2029-05-29 | 2029-05-29 | 83, 19 | 584d | 0d | Assume P2a (Roads) |  |  |
| 190 | 1.12.3.4.2 | Final Design |  | 39w | 2029-05-30 | 2030-02-26 | 189 | 584d | 0d |  |  |  |
| 191 | 1.12.3.4.3 | Procurement and NTP |  | 90d | 2030-02-27 | 2030-07-02 | 175, 190 | 584d | 295d |  |  |  |
| 192 | 1.12.3.4.4 | Southern Construction Access Roads (Maxwell-Sites, Shoo-fly, A-1) |  | 195d | 2031-08-20 | 2032-05-18 | 191, 19FS-24w, 23FS-8w | 289d | 0d |  | C1-RB3 |  |
| 193 | 1.12.3.5 | **Ancillary Roads B1, B2, C1, C2, Comm N., Comm South** |  | 505d | 2026-03-24 | 2028-02-29 |  | 2099d |  |  |  |  |
| 194 | 1.12.3.5.1 | Geotechnical Data | milestone | 0d | 2026-03-24 | 2026-03-24 | 83 | 1914d | 0d | Assume P2a (Roads) |  |  |
| 195 | 1.12.3.5.2 | Final Design |  | 39w | 2026-03-25 | 2026-12-22 | 194 | 2099d | 0d |  |  |  |
| 196 | 1.12.3.5.3 | Procurement and NTP |  | 90d | 2026-12-23 | 2027-04-27 | 175, 195 | 2099d | 0d |  |  |  |
| 197 | 1.12.3.5.4 | Ancillary Roads B1, B2, C1, C2, Comm N., Comm South |  | 220d | 2027-04-28 | 2028-02-29 | 196 | 2099d |  |  | C1-RB4 |  |
| 198 | 1.12.3.6 | **Stone Corral Recreation Road to Sites Dam** |  | 405d | 2026-03-24 | 2027-10-12 |  | 2199d |  |  |  |  |
| 199 | 1.12.3.6.1 | Geotechnical Data | milestone | 0d | 2026-03-24 | 2026-03-24 | 83 | 2014d | 0d | Does this need to be this early? If not, assume P2b |  |  |
| 200 | 1.12.3.6.2 | Final Design |  | 39w | 2026-03-25 | 2026-12-22 | 199 | 2199d | 0d |  |  |  |
| 201 | 1.12.3.6.3 | Procurement and NTP |  | 90d | 2026-12-23 | 2027-04-27 | 175, 200 | 2199d | 0d |  |  |  |
| 202 | 1.12.3.6.4 | Stone Corral Recreation Road to Sites Dam |  | 120d | 2027-04-28 | 2027-10-12 | 201 | 2199d |  |  | C1-RB5 |  |
| 203 | 1.12.3.7 | **Sites Lodoga Road Realignment and Bridge** |  | 1220d | 2026-03-24 | 2030-11-26 |  | 1384d |  |  |  |  |
| 204 | 1.12.3.7.1 | Geotechnical Data | milestone | 0d | 2026-03-24 | 2026-03-24 | 83 | 1199d | 0d | Assume P2b data date |  |  |
| 205 | 1.12.3.7.2 | Final Design |  | 78w | 2026-03-25 | 2027-09-21 | 204 | 1384d | 0d |  |  |  |
| 206 | 1.12.3.7.3 | Procurement and NTP |  | 150d | 2027-09-22 | 2028-04-18 | 175, 205 | 1384d | 0d |  |  |  |
| 207 | 1.12.3.7.4 | Sites Lodoga Road Realignment and Bridge |  | 680d | 2028-04-19 | 2030-11-26 | 206 | 1384d |  |  | C1-RB6 |  |

| ID | WBS | Task | Duration | Start | Finish | Predecessors | Total slack | Free slack | Construction Package |
| --- | --- | --- | --- | --- | --- | --- | --- | --- | --- |
| 208 | 1.12.4 | **Process and Haul Filter Materials to Project** | 2210d | 2026-12-23 | 2035-06-12 |  | 289d |  |  |
| 209 | 1.12.4.1 | Offsite Quarry Development | 50d | 2026-12-23 | 2027-03-02 | 81, 115, 175 | 1619d | 0d |  |
| 210 | 1.12.4.2 | Process Filter Materials | 800d | 2027-03-03 | 2030-03-26 | 174, 209 | 1619d | 1330d |  |
| 211 | 1.12.4.3 | Filter Material Haul to Stockpile | 800d | 2032-05-19 | 2035-06-12 | 210SS+30d, 187, 192 | 289d | 104d | C1-FM1 |
| 212 | 1.12.5 | **Saddle Dams Construction** | 2294d | 2025-09-03 | 2034-06-19 |  | 455d |  |  |
| 213 | 1.12.5.1 | **Saddle Dam 3** | 535d | 2032-06-01 | 2034-06-19 |  | 455d |  |  |
| 214 | 1.12.5.1.1 | **Saddle Dam 3 Foundation Excavation** | 180d | 2032-06-01 | 2033-02-07 |  | 455d |  |  |
| 215 | 1.12.5.1.1.1 | Saddle Dam 3 - Access and Staging | 50d | 2032-06-01 | 2032-08-09 | 170, 175, 182 | 455d | 0d |  |
| 216 | 1.12.5.1.1.2 | Erosion and Sediment Control | 50d | 2032-06-01 | 2032-08-09 | 215SS | 505d | 0d |  |
| 217 | 1.12.5.1.1.3 | Clearing / Grubbing Topsoil Salvage from Work Areas | 50d | 2032-06-01 | 2032-08-09 | 215SS | 455d | 0d |  |
| 218 | 1.12.5.1.1.4 | Demolition | 5d | 2032-06-15 | 2032-06-21 | 215SS+10d | 495d | 40d |  |
| 219 | 1.12.5.1.1.5 | Saddle Dam 3 - Foundation Excavation (Dbl Shift) | 110d | 2032-09-07 | 2033-02-07 | 215SS+20d, 216SS+20d, 217FS+20d, 218SS+20d, 170 | 455d | 0d | C1-SD3.1 |
| 220 | 1.12.5.1.2 | **Saddle Dam 3 - Foundation Preparation and Grouting** | 175d | 2032-10-12 | 2033-06-13 |  | 455d |  | C1-SD3.2 |
| 221 | 1.12.5.1.2.1 | Foundation Cleaning | 100d | 2032-10-12 | 2033-02-28 | 219FF+15d | 500d | 45d |  |
| 222 | 1.12.5.1.2.2 | Dental Excavation and Concrete | 50d | 2032-12-28 | 2033-03-07 | 219FF+20d, 221SS+10d | 455d | 0d |  |
| 223 | 1.12.5.1.2.3 | Grout Cap | 80d | 2033-01-25 | 2033-05-16 | 222SS+20d | 455d | 0d |  |
| 224 | 1.12.5.1.2.4 | Curtain Grouting | 90d | 2033-02-08 | 2033-06-13 | 223SS+10d | 455d | 0d |  |
| 225 | 1.12.5.1.3 | **Saddle Dam 3 - Embankment** | 485d | 2032-08-10 | 2034-06-19 |  | 455d |  | C1-SD3.3 |
| 226 | 1.12.5.1.3.1 | Initial Borrow Development (Core Material) | 40d | 2032-08-10 | 2032-10-04 | 215, 216, 217 | 625d | 170d |  |
| 227 | 1.12.5.1.3.2 | Initial Borrow Development for Zones 3 and 4 | 100d | 2032-08-10 | 2032-12-27 | 215, 216, 217 | 545d | 90d |  |
| 228 | 1.12.5.1.3.3 | Place Zone 1 - Core | 260d | 2033-05-03 | 2034-05-01 | 226SS+20d, 224SS+60d, 170 | 455d | 0d |  |
| 229 | 1.12.5.1.3.4 | Place Zone 2A & 2B - Filters, Drains and Transitions | 260d | 2033-05-03 | 2034-05-01 | 228SS, 182, 186, 170, 211SS+30d | 455d | 0d |  |
| 230 | 1.12.5.1.3.5 | Place Zone 3 - Rockfill | 260d | 2033-05-03 | 2034-05-01 | 229SS, 227, 170 | 455d | 0d |  |
| 231 | 1.12.5.1.3.6 | Place Zone 4 - Random | 260d | 2033-05-03 | 2034-05-01 | 230SS, 227, 170 | 455d | 0d |  |
| 232 | 1.12.5.1.3.7 | Place Rip Rap | 200d | 2033-08-16 | 2034-05-22 | 231FF+15d | 455d | 0d |  |
| 233 | 1.12.5.1.3.8 | Site Reclamation and Topsoil Replacement | 60d | 2034-03-28 | 2034-06-19 | 232FF+20d | 455d |  |  |

Notes:
- 233: Changed to 60 Days, add FF logic

| ID | WBS | Task | Duration | Start | Finish | Predecessors | Total slack | Free slack | Construction Package |
| --- | --- | --- | --- | --- | --- | --- | --- | --- | --- |
| 234 | 1.12.5.2 | **Saddle Dam 5** | 265d | 2032-06-01 | 2033-06-06 |  | 725d |  |  |
| 235 | 1.12.5.2.1 | **Saddle Dam 5 - Foundation Excavation** | 70d | 2032-06-01 | 2032-09-06 |  | 725d |  |  |
| 236 | 1.12.5.2.1.1 | Saddle Dam 5 - Access and Staging | 30d | 2032-06-01 | 2032-07-12 | 170, 175, 182 | 725d | 0d |  |
| 237 | 1.12.5.2.1.2 | Erosion and Sediment Control | 30d | 2032-06-01 | 2032-07-12 | 236SS | 730d | 0d |  |
| 238 | 1.12.5.2.1.3 | Clearing / Grubbing Topsoil Salvage from Work Areas | 30d | 2032-06-01 | 2032-07-12 | 236SS | 730d | 0d |  |
| 239 | 1.12.5.2.1.4 | Demolition | 5d | 2032-06-15 | 2032-06-21 | 236SS+10d | 735d | 5d |  |
| 240 | 1.12.5.2.1.5 | Saddle Dam 5 - Foundation Excavation | 50d | 2032-06-29 | 2032-09-06 | 236SS+20d, 237SS+20d, 238SS+20d, 239, 98 | 730d | 0d | C1-SD5.1 |
| 241 | 1.12.5.2.2 | **Saddle Dam 5 - Foundation Preparation and Grouting** | 110d | 2032-07-06 | 2032-12-06 |  | 730d |  | C1-SD5.2 |
| 242 | 1.12.5.2.2.1 | Foundation Cleaning | 60d | 2032-07-06 | 2032-09-27 | 240FF+15d | 730d | 0d |  |
| 243 | 1.12.5.2.2.2 | Dental Excavation and Concrete | 60d | 2032-07-20 | 2032-10-11 | 240FF+15d, 242SS+10d | 730d | 0d |  |
| 244 | 1.12.5.2.2.3 | Grout Cap | 40d | 2032-08-17 | 2032-10-11 | 243SS+20d | 730d | 0d |  |
| 245 | 1.12.5.2.2.4 | Curtain Grouting | 70d | 2032-08-31 | 2032-12-06 | 244SS+10d | 730d | 0d |  |
| 246 | 1.12.5.2.3 | **Saddle Dam 5 - Embankment** | 235d | 2032-07-13 | 2033-06-06 |  | 725d |  | C1-SD5.3 |
| 247 | 1.12.5.2.3.1 | Initial Borrow Development (Core Material) | 40d | 2032-07-13 | 2032-09-06 | 236 | 805d | 75d |  |
| 248 | 1.12.5.2.3.2 | Initial Borrow Development for Zones 3 and 4 | 100d | 2032-07-13 | 2032-11-29 | 236 | 725d | 0d |  |
| 249 | 1.12.5.2.3.3 | Place Zone 1 - Core | 100d | 2032-11-23 | 2033-04-11 | 245SS+60d, 247SS+20d, 170 | 730d | 0d |  |
| 250 | 1.12.5.2.3.4 | Place Zone 2A & 2B - Filters, Drains and Transitions | 100d | 2032-11-23 | 2033-04-11 | 249SS, 182, 186, 211SS+30d | 730d | 5d |  |
| 251 | 1.12.5.2.3.5 | Place Zone 3 - Rockfill | 100d | 2032-11-30 | 2033-04-18 | 250SS, 248 | 725d | 0d |  |
| 252 | 1.12.5.2.3.6 | Place Zone 4 - Random | 100d | 2032-11-30 | 2033-04-18 | 251SS | 725d | 0d |  |
| 253 | 1.12.5.2.3.7 | Place Rip Rap | 70d | 2033-02-01 | 2033-05-09 | 252FF+15d | 725d | 0d |  |
| 254 | 1.12.5.2.3.8 | Site Reclamation and Topsoil Replacement | 60d | 2033-03-15 | 2033-06-06 | 253FF+20d | 725d |  |  |
| 255 | 1.12.5.3 | **Minor Saddle Dams (SD1,SD2,SD6,SD8A, Dike 1, and Dike 2)** | 1329d | 2028-02-09 | 2033-03-14 |  | 785d |  |  |
| 256 | 1.12.5.3.1 | **Minor Saddle Dams Foundation Excavation** | 120d | 2028-02-09 | 2028-07-25 |  | 1759d |  |  |
| 257 | 1.12.5.3.1.1 | Minor Saddle Dams - Access and Staging | 30d | 2028-02-09 | 2028-03-21 | 170, 175 | 1759d | 0d |  |
| 258 | 1.12.5.3.1.2 | Erosion and Sediment Control | 30d | 2028-02-09 | 2028-03-21 | 257SS | 1738d | 0d |  |
| 259 | 1.12.5.3.1.3 | Clearing / Grubbing Topsoil Salvage from Work Areas | 30d | 2028-02-09 | 2028-03-21 | 257SS | 1738d | 0d |  |
| 260 | 1.12.5.3.1.4 | Demolition | 5d | 2028-02-23 | 2028-02-29 | 257SS+10d | 1769d | 5d |  |
| 261 | 1.12.5.3.1.5 | Minor Saddle Dams - Foundation Excavation | 100d | 2028-03-08 | 2028-07-25 | 257SS+20d, 258SS+20d, 259SS+20d, 260, 170 | 1764d | 0d | C1-SDM.1 |

Notes:
- 254: Changed to 60 Days, add FF logic

| ID | WBS | Task | Duration | Start | Finish | Predecessors | Total slack | Free slack | Construction Package |
| --- | --- | --- | --- | --- | --- | --- | --- | --- | --- |
| 262 | 1.12.5.3.2 | **Minor Saddle Dams - Foundation Preparation and Grouting** | 190d | 2028-03-29 | 2028-12-19 |  | 1764d |  | C1-SDM.2 |
| 263 | 1.12.5.3.2.1 | Foundation Cleaning | 100d | 2028-03-29 | 2028-08-15 | 261FF+15d | 1743d | 0d |  |
| 264 | 1.12.5.3.2.2 | Dental Excavation and Concrete | 100d | 2028-04-12 | 2028-08-29 | 261FF+20d, 263SS+10d | 1743d | 0d |  |
| 265 | 1.12.5.3.2.3 | Grout Cap | 80d | 2028-05-24 | 2028-09-12 | 264SS+30d | 1764d | 0d |  |
| 266 | 1.12.5.3.2.4 | Curtain Grouting | 140d | 2028-06-07 | 2028-12-19 | 265SS+10d | 1764d | 0d |  |
| 267 | 1.12.5.3.3 | **Minor Saddle Dams - Embankment** | 1299d | 2028-03-22 | 2033-03-14 |  | 785d |  | C1-SDM.3 |
| 268 | 1.12.5.3.3.1 | Initial Borrow Development (Core Material) | 40d | 2028-03-22 | 2028-05-16 | 257, 258, 259 | 1859d | 95d |  |
| 269 | 1.12.5.3.3.2 | Initial Borrow Development for Zones 3 and 4 | 120d | 2028-03-22 | 2028-09-05 | 257, 258, 259 | 1759d | 974d |  |
| 270 | 1.12.5.3.3.3 | Place Zone 1 - Core | 175d | 2028-08-30 | 2029-05-01 | 266SS+60d, 268SS+20d, 170 | 1764d | 979d |  |
| 271 | 1.12.5.3.3.4 | Place Zone 2A & 2B - Filters, Drains and Transitions | 175d | 2032-06-01 | 2033-01-31 | 270SS, 182, 186, 170 | 785d | 0d |  |
| 272 | 1.12.5.3.3.5 | Place Zone 3 - Rockfill | 175d | 2032-06-01 | 2033-01-31 | 271SS, 170, 269 | 785d | 0d |  |
| 273 | 1.12.5.3.3.6 | Place Zone 4 - Random | 175d | 2032-06-01 | 2033-01-31 | 272SS, 170, 269 | 785d | 0d |  |
| 274 | 1.12.5.3.3.7 | Place Rip Rap | 145d | 2032-07-27 | 2033-02-14 | 273FF+10d | 785d | 0d |  |
| 275 | 1.12.5.3.3.8 | Site Reclamation and Topsoil Replacement | 60d | 2032-12-21 | 2033-03-14 | 274FF+20d | 785d |  |  |
| 276 | 1.12.5.4 | **Saddle Dam 8B - Spillway** | 922d | 2025-09-03 | 2029-03-15 |  | 1827d |  | C1-SD8B.1 |
| 277 | 1.12.5.4.1 | Batch Plant Setup and Operational | 50d | 2028-03-22 | 2028-05-30 | 257, 170 | 1827d | 0d |  |
| 278 | 1.12.5.4.2 | SD 8B - Foundation Excavation | 20d | 2028-03-22 | 2028-04-18 | 257, 258, 259, 170 | 1827d | 0d |  |
| 279 | 1.12.5.4.3 | SD 8B - Foundation Cleaning | 20d | 2028-04-19 | 2028-05-16 | 278 | 1827d | 0d |  |
| 280 | 1.12.5.4.4 | SD 8B - Dental Excavation and Concrete | 20d | 2028-05-03 | 2028-05-30 | 279SS+10d | 1827d | 0d |  |
| 281 | 1.12.5.4.5 | SD 8B - Grout Cap | 12d | 2028-05-31 | 2028-06-15 | 280, 277 | 1827d | 0d |  |
| 282 | 1.12.5.4.6 | SD 8B - Foundation Grouting | 45d | 2028-06-16 | 2028-08-17 | 281 | 1827d | 0d |  |
| 283 | 1.12.5.4.7 | SD 8B - Mass Concrete | 120d | 2028-08-18 | 2029-02-01 | 282 | 1827d | 0d |  |
| 284 | 1.12.5.4.8 | SD 8B - Bridge | 30d | 2029-02-02 | 2029-03-15 | 283 | 1827d |  |  |
| 285 | 1.12.5.4.9 | SD 8B - Clay Backfill | 20d | 2028-11-10 | 2028-12-07 | 283SS+60d | 1894d | 0d |  |
| 286 | 1.12.5.4.10 | SD 8B - Riprap and Drain Gravel | 3d | 2028-12-08 | 2028-12-12 | 285 | 1894d |  |  |
| 287 | 1.12.5.4.11 | Rim Grouting | 171d | 2025-09-03 | 2026-04-29 | 177 | 2557d |  |  |

Notes:
- 275: Changed to 60 Days, add FF logic

| ID | WBS | Task | Duration | Start | Finish | Predecessors | Total slack | Free slack | Construction Package |
| --- | --- | --- | --- | --- | --- | --- | --- | --- | --- |
| 288 | 1.12.6 | **Sites Dam Construction** | 585d | 2032-05-19 | 2034-08-15 |  | 464d |  |  |
| 289 | 1.12.6.1 | **Sites Dam Foundation Excavation** | 230d | 2032-05-19 | 2033-04-05 |  | 464d |  |  |
| 290 | 1.12.6.1.1 | Sites Dam Access and Staging | 100d | 2032-05-19 | 2032-10-05 | 192, 134, 175 | 464d | 0d |  |
| 291 | 1.12.6.1.2 | Erosion and Sediment Control | 100d | 2032-05-19 | 2032-10-05 | 290SS | 474d | 0d |  |
| 292 | 1.12.6.1.3 | Clearing / Grubbing Topsoil Salvage from Work Areas | 100d | 2032-05-19 | 2032-10-05 | 290SS | 474d | 0d |  |
| 293 | 1.12.6.1.4 | Demolition | 50d | 2032-06-02 | 2032-08-10 | 290SS+10d | 464d | 0d |  |
| 294 | 1.12.6.1.5 | Sites Dam - Foundation Excavation | 200d | 2032-06-30 | 2033-04-05 | 290SS+20d, 291SS+20d, 292SS+20d, 293SS+20d, 98 | 464d | 0d | C1-Sites.1 |
| 295 | 1.12.6.2 | **Sites Diversion Outlet Facility** | 570d | 2032-06-09 | 2034-08-15 |  | 504d |  | C1-Sites.2 |
| 296 | 1.12.6.2.1 | Develop Downstream Portal | 90d | 2032-06-09 | 2032-10-12 | 290SS+15d, 134 | 504d | 0d |  |
| 297 | 1.12.6.2.2 | Tunnel Excavation and Lining - Double Shift | 300d | 2032-10-13 | 2033-12-06 | 296 | 504d | 0d |  |
| 298 | 1.12.6.2.3 | Develop Upstream Portal | 90d | 2032-06-09 | 2032-10-12 | 290SS+15d | 804d | 300d |  |
| 299 | 1.12.6.2.4 | Outlet Structure Concrete | 70d | 2033-12-07 | 2034-03-14 | 297 | 504d | 0d |  |
| 300 | 1.12.6.2.5 | Inlet Structure Concrete | 70d | 2033-12-07 | 2034-03-14 | 297, 298 | 504d | 0d |  |
| 301 | 1.12.6.2.6 | Mechanical | 70d | 2034-03-15 | 2034-06-20 | 297, 299, 300 | 504d | 0d |  |
| 302 | 1.12.6.2.7 | Sites Diversion Completion and Restoration | 20d | 2034-06-21 | 2034-07-18 | 299, 300, 301 | 504d | 0d |  |
| 303 | 1.12.6.2.8 | Construct Cofferdam to El. 310 | 20d | 2034-07-19 | 2034-08-15 | 294SS+30d, 302 | 504d |  |  |
| 304 | 1.12.6.3 | **Sites Dam - Foundation Preparation and Grouting** | 165d | 2032-11-10 | 2033-06-28 |  | 489d |  | C1-Sites.3 |
| 305 | 1.12.6.3.1 | Foundation Cleaning | 120d | 2032-11-10 | 2033-04-26 | 294FF+15d | 844d |  |  |
| 306 | 1.12.6.3.2 | Dental Excavation and Concrete | 100d | 2032-12-15 | 2033-05-03 | 294FF+20d | 464d | 0d |  |
| 307 | 1.12.6.3.3 | Grout Cap | 80d | 2033-01-12 | 2033-05-03 | 306SS+20d, 146 | 464d | 0d |  |
| 308 | 1.12.6.3.4 | Consolidation Grouting | 80d | 2033-01-26 | 2033-05-17 | 307SS+10d | 464d | 0d |  |
| 309 | 1.12.6.3.5 | Curtain Grouting | 100d | 2033-02-09 | 2033-06-28 | 308SS+10d | 464d | 0d |  |
| 310 | 1.12.6.4 | **Sites Dam - Embankment** | 435d | 2032-10-06 | 2034-06-06 |  | 464d |  | C1-Sites.4 |
| 311 | 1.12.6.4.1 | Initial Borrow Development (Core Material) | 40d | 2032-10-06 | 2032-11-30 | 290, 291, 292 | 584d | 120d |  |
| 312 | 1.12.6.4.2 | Initial Quarry Development for Zones 3 and 4 | 120d | 2032-10-06 | 2033-03-22 | 290, 291, 292 | 564d | 100d |  |
| 313 | 1.12.6.4.3 | Place Zone 1 - Core | 250d | 2033-04-20 | 2034-04-04 | 311SS+20d, 309SS+50d, 158 | 464d | 0d |  |
| 314 | 1.12.6.4.4 | Place Zone 2A & 2B - Filters, Drains and Transitions | 250d | 2033-04-20 | 2034-04-04 | 313SS, 192, 158, 211SS+30d | 464d | 0d |  |
| 315 | 1.12.6.4.5 | Place Zone 3 - Rockfill (Some Dbl Shift) | 250d | 2033-04-20 | 2034-04-04 | 314SS, 312SS+40d, 158 | 464d | 0d |  |
| 316 | 1.12.6.4.6 | Place Zone 4 - Random (Some Dbl Shift) | 250d | 2033-04-20 | 2034-04-04 | 315SS, 158 | 464d | 0d |  |
| 317 | 1.12.6.4.7 | Place Rip Rap | 200d | 2033-07-20 | 2034-04-25 | 316FF+15d | 464d | 0d |  |
| 318 | 1.12.6.4.8 | Site Reclamation and Topsoil Replacement | 70d | 2034-03-01 | 2034-06-06 | 317FF+30d | 464d |  |  |

| ID | WBS | Task | Type | Duration | Start | Finish | Predecessors | Total slack | Free slack | Dave Hardy notes | Construction Package |
| --- | --- | --- | --- | --- | --- | --- | --- | --- | --- | --- | --- |
| 319 | 1.12.7 | **Golden Gate Dam Construction** |  | 990d | 2032-06-01 | 2036-03-17 |  | 0d |  |  |  |
| 320 | 1.12.7.1 | **GG Dam Foundation Excavation** |  | 360d | 2032-06-01 | 2033-10-17 |  | 0d |  |  |  |
| 321 | 1.12.7.1.1 | Golden Gate Access and Staging |  | 100d | 2032-06-01 | 2032-10-18 | 175, 98, 57, 66, 68, 71, 44, 187, 182 | 0d |  | Added 189 as Predecessor, already had 184 |  |
| 322 | 1.12.7.1.2 | Erosion and Sediment Control |  | 100d | 2032-06-01 | 2032-10-18 | 321SS | 140d | 0d |  |  |
| 323 | 1.12.7.1.3 | Clearing / Grubbing Topsoil Salvage from Work Areas |  | 100d | 2032-06-01 | 2032-10-18 | 321SS | 140d | 0d |  |  |
| 324 | 1.12.7.1.4 | Demolition |  | 50d | 2032-06-15 | 2032-08-23 | 321SS+10d | 130d |  |  |  |
| 325 | 1.12.7.1.5 | GG Dam - Foundation Excavation (Some Dbl Shift) |  | 200d | 2033-01-11 | 2033-10-17 | 321SS+20d, 322SS+20d, 323SS+20d, 324SS+20d, 98, 79FF | 0d |  |  | C1-GG.1 |
| 326 | 1.12.7.1.6 | GG Dam - Bypass Pipeline and U/S Cofferdam |  | 70d | 2033-05-31 | 2033-09-05 | 321SS+100d, 322SS+100d, 323SS+100d, 324SS+100d, 325SS+100d | 90d |  |  | C1-GG.2 |
| 327 | 1.12.7.2 | **GG Dam - Foundation Preparation and Grouting** |  | 215d | 2033-06-21 | 2034-04-17 |  | 0d |  |  | C1-GG.3 |
| 328 | 1.12.7.2.1 | Foundation Cleaning |  | 100d | 2033-06-21 | 2033-11-07 | 325FF+15d | 15d |  |  |  |
| 329 | 1.12.7.2.2 | Dental Excavation and Concrete |  | 80d | 2033-07-26 | 2033-11-14 | 325FF+20d, 328SS+10d | 0d |  |  |  |
| 330 | 1.12.7.2.3 | Grout Cap |  | 100d | 2033-08-23 | 2034-01-09 | 329SS+20d, 109 | 0d |  |  |  |
| 331 | 1.12.7.2.4 | Consolidation Grouting |  | 125d | 2033-09-06 | 2034-02-27 | 330SS+10d | 0d |  |  |  |
| 332 | 1.12.7.2.5 | Curtain Grouting |  | 150d | 2033-09-20 | 2034-04-17 | 331SS+10d | 0d |  |  |  |
| 333 | 1.12.7.3 | **GG Dam - Embankment** |  | 890d | 2032-10-19 | 2036-03-17 |  | 0d |  |  | C1-GG.4 |
| 334 | 1.12.7.3.1 | Initial Borrow Development (Core Material) |  | 40d | 2032-10-19 | 2032-12-13 | 321, 322, 323 | 300d |  |  |  |
| 335 | 1.12.7.3.2 | Initial Borrow Development for Zones 3 and 4 |  | 120d | 2032-10-19 | 2033-04-04 | 321, 322, 323 | 280d |  |  |  |
| 336 | 1.12.7.3.3 | Place Zone 1 - Core |  | 525d | 2034-01-10 | 2036-01-14 | 334SS+20d, 332SS+80d, 121, 326 | 0d |  |  |  |
| 337 | 1.12.7.3.4 | Place Zone 2A & 2B - Filters, Drains and Transitions |  | 525d | 2034-01-10 | 2036-01-14 | 336SS, 192, 182, 121, 211SS+30d | 0d |  |  |  |
| 338 | 1.12.7.3.5 | Place Zone 3 - Rockfill (Some Dbl Shift) |  | 525d | 2034-01-10 | 2036-01-14 | 337SS, 335SS+40d, 121 | 0d |  |  |  |
| 339 | 1.12.7.3.6 | Place Zone 4 - Random (Some Dbl Shift) |  | 525d | 2034-01-10 | 2036-01-14 | 338SS, 121 | 0d |  |  |  |
| 340 | 1.12.7.3.7 | Place Rip Rap |  | 475d | 2034-04-11 | 2036-02-04 | 339FF+15d | 0d |  |  |  |
| 341 | 1.12.7.3.8 | Site Reclamation and Topsoil Replacement |  | 120d | 2035-10-02 | 2036-03-17 | 340FF+30d | 0d |  |  |  |
| 342 | 1.12.8 | Dams Ready for Commissioning | milestone | 0d | 2036-03-17 | 2036-03-17 | 287, 207, 202, 318, 341, 286, 284, 254, 233, 197, 25, 23, 275 | 0d |  |  |  |
| 343 | 1.12.9 | Dams Startup and Commissioning |  | 90d | 2036-03-18 | 2036-07-21 | 342 | 0d |  |  |  |
| 344 | 1.12.10 | Substantial Completion | milestone | 0d | 2036-07-21 | 2036-07-21 | 343 | 0d |  |  |  |
